Schedule from MS Project, 2002-01-01 to 2005-09-01, 24 hours a day.
NAMA SA

## Calendars

- 24 Hours: Mon-Sun 00:00-24:00.

## Resources

| Resource |
| --- |
| Εργοδότης |
| Προιστάμενη Αρχή |
| Διευθύνουσα Υπηρεσία |
| Γενικός Μελετητής |
| Αλλοι τοπικοί φορείς |
| Δνση Χωροταξίας ΥΠΕΧΩΔΕ |
| ΓΓ Περίφέρειας |
| ΥΠΕΧΩΔΕ/Περιβάλλον |
| Δ/νση Γεωργίας |
| Δνση Περιβαλλοντικού Σχεδιασμού ΥΠΕΧΩΔΕ |
| Δνση Περιβαλλοντος και Χωροταξίας Γενικής Γραμματείας της Περιφέρειας |
| Ενδιαφερόμενο Κοινό |
| Κύριος του Έργου |
| Συναρμόδιες Υπηρεσίες |
| Δ/νση Υγιεινής-Δνση Περιβάλλοντος-Δνση Τεχνικών Υπηρεσιών Νομαρχίας |
| Εμπλεκόμενοι Δήμοι ή Κοινότητες |
| Άμεσα ενδιαφερόμενες Υπηρεσίες |
| Φορέας σχεδιασμού |
| Δ.Σ. της ΔΕΥΑ |
| ΤΥΔΚ Περιφέρειας |
| Τμήμα Πρωτοβ.Τοπικής Υπηρεσίας Περιφέρειας |
| ΓΕΜ |
| Τεχνική Υπηρεσία ΟΤΑ ή ΔΕΥΑ ή ΤΥΔΚ |
| Εφορείες αρχαιοτήτων |
| Δασική Υπηρεσία |
| ΝΕΧΩΠ |
| ΕΥΠΕ/ΥΠΕΧΩΔΕ |
| Οργανισμός Αθήνας/ Θεσσαλονίκης |
| Δ/νσεις ΠΕ.ΧΩ. Περιφερειών |
| Δ/νσεις Περιβάλλοντος των Νομαρχιακών Διαμερισμάτων της ΝΑ Αττικής |
| Αρμόδιες ΔΟΥ |
| Αρμόδια Μονομέλή Πρωτοδικεία Νομών |
| Τεχν. Υπηρ. Δήμου ή Κοινότητας ή της ΔΕΥΑ |
| Δ/νση Τεχν. Υπηρ. Του ΥΠ.ΕΣ.Δ.Δ.Α |
| ΔΤΥ ΥΠ.ΕΣ.Δ.Δ.Α |
| ΔΥΠ |
| Δ/νση Πολεοδομικού Σχεδιασμού ΥΠΕΧΩΔΕ |
| Δ/νσεις Συναρμοδίων Υπουργείων |
| Δ/νση ΠΕ.ΧΩ. Τμήμα Περιβάλλοντος της Περιφέρειας |
| Νομαρχιακό Συμβούλιο |
| Αρμόδιες Υπηρεσίες χρηματοδοτήσεων (ΥΠ.ΕΘ.Ο. -ΥΠ.ΕΣ. - Περιφ.) |
| Επιτροπή Προεπιλογής Υποψήφιων Αναδόχων |
| Επιτροπή Παραλαβής προσφορών |
| Υποψήφιοι Ανάδοχοι του Έργου |
| Επιτροπή Εισήγησης για Ανάθεση |
| Ανάδοχος |
| Δνση Υγιεινής |
| ΔΤΥΝΑ Νομαρχίας |
| Δ/νση Πολεοδομίας της Ν.Α. |
| Τμήμα Πρωτοβα.Τοπικής Υπηρεσίας Περιφέρειας |
| ΤΕΔΚ |
| Νομάρχης ή Γενικός Γραμματέας της Περιφέρειας |
| Ειδική Γνωμοδοτική Επιτροπή σε επίπεδο Νομού ή Περιφέρειας |
| Αρμόδιο Γραφείο Κτηματολογίου ή Αρμόδιο Υποθηκοφυλάκιο |
| Αρμόδιο Πολεοδομικό Γραφείο ή Δ/νση Πολεοδομίας |
| Ιδιοκτήτης του Οικοπέδου |
| Οικονομικές Εφορίες |
| Συμβούλιο Δημοτικών και Κοινοτικών Έργων και Θεώρησης Μελετών του ΥΠ.ΕΣ.Δ.Δ.Α |
| Αρμόδιοι Φορείς |
| Προσφέροντες |
| Επιβλέπων της Μελέτης |
| Νομαρχιακή Αυτοδιοίκηση |
| Υπουργός ΠΕΧΩΔΕ |
| Ανάδοχος Μελετητής |

## Schedule

| ID | WBS | Task | Type | Duration | Start | Finish | Predecessors | Total slack | Free slack | Constraint | Resources | Work | Text1 |
| --- | --- | --- | --- | --- | --- | --- | --- | --- | --- | --- | --- | --- | --- |
| 1 | 1 | **Στάδιο Ι: Σχεδιασμός Διαχείρισης Στερεών Αποβλήτων - Προμελέτη Περιβαλλοντικών Επιπτώσεων** |  | 776d | 2002-01-01 | 2004-02-16 |  | 292d | 0d |  |  | 53256h | 26.5Μ |
| 2 | 1.1 | Ανάθεση Εκπόνησης Α' και Β' Φάσης |  | 135d | 2002-01-01 | 2002-05-16 |  | 263d | 3d |  |  |  | 4.5Μ |
| 3 | 1.1 | **Α΄Φάση Σχεδιασμού: Κατάρτιση - Έγκριση Πλαισίου Σχεδιασμού** |  | 242d | 2002-05-19 | 2003-01-16 | 2 | 292d | 0d |  |  | 11520h | 13.5Μ |
| 4 | 1.1.2 | Εκπόνηση Πλαισίου Σχεδιασμού |  | 227d | 2002-05-19 | 2003-01-01 |  | 292d | 0d | finish no earlier than 2003-01-01 | Ανάδοχος; Συναρμόδιες Υπηρεσίες | 9360h | 6.5 |
| 5 | 1.1.3 | Αποστολή Πλαισίου Σχεδιασμού στην Περιφέρεια |  | 30d | 2002-11-01 | 2002-12-01 |  | 306d |  | start no earlier than 2002-11-01 | Νομαρχιακή Αυτοδιοίκηση; Υπουργός ΠΕΧΩΔΕ | 1440h | 1Μ |
| 6 | 1.1.4 | Έγκριση Πλαισίου Σχεδιασμού |  | 15d | 2003-01-01 | 2003-01-16 | 4 | 260d |  |  | Νομαρχιακό Συμβούλιο; ΤΕΔΚ | 720h | 0.5Μ |
| 7 | 1.2 | **Β΄Φάση Σχεδιασμού: Κυρίως Μελέτη Σχεδιασμού** |  | 198d | 2003-01-16 | 2003-08-02 | 3 | 292d | 0d |  |  | 6480h | 7Μ |
| 8 | 1.2.2 | Εκπόνηση Κυρίως Μελέτης Σχεδιασμού |  | 138d | 2003-01-16 | 2003-06-03 |  | 260d | 0d |  | Ανάδοχος | 3240h | 4.5Μ |
| 9 | 1.2.3 | Σύσταση Επιτροπής για την Έγκριση των Χώρων - Γνωμοδότηση Επιτροπής |  | 30d | 2003-06-03 | 2003-07-03 | 8 | 260d | 0d |  | Νομάρχης ή Γενικός Γραμματέας της Περιφέρειας; Ειδική Γνωμοδοτική Επιτροπή σε επίπεδο Νομού ή Περιφέρειας | 1440h | 1Μ |
| 10 | 1.2.4 | Έγκριση Κυρίως Μελέτης Σχεδιασμού |  | 15d | 2003-07-03 | 2003-07-18 | 9 | 260d | 0d |  | Νομάρχης ή Γενικός Γραμματέας της Περιφέρειας; Ειδική Γνωμοδοτική Επιτροπή σε επίπεδο Νομού ή Περιφέρειας; Νομαρχιακό Συμβούλιο | 1080h | 0.5Μ |
| 11 | 1.2.5 | Αποστολή Φακέλου στη Διεύθυνση ΠΕΧΩ της Περιφέρειας και στη Δ/νση Περιβαλλοντικού Σχεδιασμού του ΥΠΕΧΩΔΕ |  | 15d | 2003-07-18 | 2003-08-02 | 10 | 260d |  |  | Δ/νσεις ΠΕ.ΧΩ. Περιφερειών; Δνση Περιβαλλοντικού Σχεδιασμού ΥΠΕΧΩΔΕ | 720h | 0.5Μ |
| 12 | 1.3 | **Εκπόνηση Προμελέτης Περιβαλλοντικών Επιπτώσεων - Π.Π.Ε. (Π. Χ.)** |  | 213d | 2003-07-18 | 2004-02-16 | 7FS-15d | 292d |  |  |  | 35256h | 8Μ |
| 13 | 1.3.2 | Εκπόνηση Π.Π.Ε. (Π.Χ.) |  | 105d | 2003-07-18 | 2003-10-31 |  | 260d | 0d |  | Ανάδοχος; Διευθύνουσα Υπηρεσία; Δασική Υπηρεσία; Εφορείες αρχαιοτήτων; Νομάρχης ή Γενικός Γραμματέας της Περιφέρειας; Ειδική Γνωμοδοτική Επιτροπή σε επίπεδο Νομού ή Περιφέρειας; Αρμόδιο Γραφείο Κτηματολογίου ή Αρμόδιο Υποθηκοφυλάκιο; Αρμόδιο Πολεοδομικό Γραφείο ή Δ/νση Πολεοδομίας; Δ/νση Γεωργίας | 22680h | 3.5Μ |
| 14 | 1.3.3 | Έγκριση Π.Π.Ε. (Π.Χ.) |  | 16d | 2003-10-31 | 2003-11-16 | 13 | 260d | 0d |  | Διευθύνουσα Υπηρεσία; Ανάδοχος | 768h | 0.5Μ |
| 15 | 1.3.4 | Έκδοση Απόφασης Προκαταρκτικής Περιβαλλοντικής Εκτίμησης και Αξιολόγησης (Π.Χ.) |  | 77d | 2003-11-16 | 2004-02-01 | 14 | 260d | 0d |  | Διευθύνουσα Υπηρεσία; ΕΥΠΕ/ΥΠΕΧΩΔΕ; Δνση Περιβαλλοντος και Χωροταξίας Γενικής Γραμματείας της Περιφέρειας; Οργανισμός Αθήνας/ Θεσσαλονίκης; ΓΓ Περίφέρειας; Υπουργός ΠΕΧΩΔΕ | 11088h | 2.5Μ |
| 16 | 1.3.5 | Απόστολή Αποφάσης Π.Π.Ε.Α (Π.Χ.) στη Δ/νση Περιβαλλοντικού Σχεδιασμού του ΥΠΕΧΩΔΕ |  | 15d | 2004-02-01 | 2004-02-16 | 15 | 260d |  |  | Φορέας σχεδιασμού; Δνση Περιβαλλοντικού Σχεδιασμού ΥΠΕΧΩΔΕ | 720h | 0.5Μ |
| 17 | 2 | **Στάδιο ΙΙ: Απόκτηση Γης** |  | 285d | 2004-02-02 | 2004-11-13 | 1FS-14d | 292d | 0d |  |  | 27360h | 9.5Μ |
| 18 | 2.1 | Διαδικασίες για την Απόκτηση Οικοπέδου |  | 285d | 2004-02-02 | 2004-11-13 |  | 260d |  |  | Κύριος του Έργου; Ιδιοκτήτης του Οικοπέδου; Οικονομικές Εφορίες; Αρμόδια Μονομέλή Πρωτοδικεία Νομών | 27360h | 9.5Μ |
| 19 | 3 | **Στάδιο ΙΙΙ: Εκπόνηση Προμέλέτης Έργου και Μ.Π.Ε - Έγκριση Περιβαλλοντικών Όρων** |  | 517d | 2004-02-02 | 2005-07-03 | 17SS | 0d |  |  |  | 19656h | 17Μ |
| 20 | 3.1 | **Εκπόνηση Προμελέτης Έργου** |  | 517d | 2004-02-02 | 2005-07-03 |  | 0d |  |  |  | 9576h | 7.5Μ |
| 21 | 3.1.1 | Ανάθεση Εκπόνησης Προμελέτης |  | 135d | 2004-02-02 | 2004-06-16 |  | 0d |  |  | Εργοδότης [33.3%]; Προιστάμενη Αρχή [33.3%]; Διευθύνουσα Υπηρεσία [33.3%] | 3240h | 4.5Μ |
| 22 | 3.1.2 | Εκπόνηση Προμελέτης και Μελετών Υποστήριξης |  | 368d | 2004-06-16 | 2005-06-19 | 21 | 0d |  |  | Διευθύνουσα Υπηρεσία; Ανάδοχος | 5328h | 3.5Μ |
| 23 | 3.1.3 | Έγκριση Προμελέτης και Μελετών Υποστήριξης |  | 14d | 2005-06-19 | 2005-07-03 | 22 | 0d |  |  | Διευθύνουσα Υπηρεσία; ΔΤΥ ΥΠ.ΕΣ.Δ.Δ.Α; Συμβούλιο Δημοτικών και Κοινοτικών Έργων και Θεώρησης Μελετών του ΥΠ.ΕΣ.Δ.Δ.Α | 1008h | 0.5Μ |
| 24 | 3.2 | **Εκπόνηση Μελέτης Περιβαλλοντικών Επιπτώσεων - Μ.Π.Ε. και Έγκριση Περιβαλλοντικών Όρων** |  | 260d | 2004-09-15 | 2005-06-02 |  | 31d |  |  |  | 10080h | 9.5Μ |
| 25 | 3.2.1 | Ανάθεση Εκπόνησης Μ.Π.Ε | milestone | 0d | 2004-09-15 | 2004-09-15 |  | 31d | 0d | start no earlier than 2004-09-15 |  |  | 0Μ |
| 26 | 3.2.2 | Εκπόνηση Μ.Π.Ε |  | 110d | 2004-09-15 | 2005-01-03 | 25 | 31d | 0d |  | Διευθύνουσα Υπηρεσία; Ανάδοχος; Αρμόδιοι Φορείς | 7920h | 3.5Μ |
| 27 | 3.2.3 | Έγκριση Μ.Π.Ε |  | 30d | 2005-01-03 | 2005-02-02 | 26 | 31d | 0d |  | Διευθύνουσα Υπηρεσία; Ανάδοχος | 1440h | 1Μ |
| 28 | 3.2.4 | Έκδοση Απόφασης Έγκρισης Περιβαλλοντικών Όρων |  | 105d | 2005-02-02 | 2005-05-18 | 27 | 31d | 0d |  |  |  | 3.5Μ |
| 29 | 3.2.5 | Αποστολή Απόφασης Έγκρισης Περιβαλλοντικών Όρων στη Δ/νση Περιβαλλοντικού Σχεδιασμού του ΥΠΕΧΩΔΕ |  | 15d | 2005-05-18 | 2005-06-02 | 28 | 31d |  |  | Φορέας σχεδιασμού; Δνση Περιβαλλοντικού Σχεδιασμού ΥΠΕΧΩΔΕ | 720h | 0.5Μ |

| ID | WBS | Task | Duration | Start | Finish | Predecessors | Total slack | Resources | Work | Text1 |
| --- | --- | --- | --- | --- | --- | --- | --- | --- | --- | --- |
| 30 | 4 | **Στάδιο ΙV: Λοιπές Ενέργειες** | 60d | 2005-07-03 | 2005-09-01 | 19 | 0d |  | 5040h | 2Μ |
| 31 | 4.1 | Σύνταξη των Τευχών Δημοπράτησης | 30d | 2005-07-03 | 2005-08-02 |  | 0d | Διευθύνουσα Υπηρεσία; Προιστάμενη Αρχή; Ανάδοχος | 2160h | 1Μ |
| 32 | 4.2 | Έγκριση των Τευχών Δημοπράτησης | 30d | 2005-08-02 | 2005-09-01 | 31 | 0d | Εργοδότης; Διευθύνουσα Υπηρεσία; ΔΤΥ ΥΠ.ΕΣ.Δ.Δ.Α; Συμβούλιο Δημοτικών και Κοινοτικών Έργων και Θεώρησης Μελετών του ΥΠ.ΕΣ.Δ.Δ.Α | 2880h | 1Μ |
