# Μεταφορά νερού_new

Schedule from MS Project, 2002-01-01 to 2004-10-31, 24 hours a day.
NAMA SA

## Calendars

- 24 Hours: Mon-Sun 00:00-24:00.

## Resources

| Resource |
| --- |
| Εργοδότης |
| Προιστάμενη Αρχή |
| Διευθύνουσα Υπηρεσία |
| Γενικός Μελετητής |
| Αλλοι τοπικοί φορείς |
| Μελετητής |
| Γεωλόγος |
| Δνση Χωροταξίας ΥΠΕΧΩΔΕ |
| ΓΓ Περίφέρειας |
| Δνση Χωροταξίας (Κεντρική ή Περιφερειακή) |
| Υπουργείο Γεωργείας |
| ΥΠΠΟ |
| ΥΠΕΧΩΔΕ/Περιβάλλον |
| Τοπογράφος |
| Γεωτεχνικός |
| Κυκλοφοριολόγος |
| Μελετητης Περιβαλλοντολόγος |
| Δνση Περιβαλλοντικού Σχεδιασμού |
| Δνση Περιβαλλοντος και Χωροταξίας Γενικής Γραμματείας της Περιφέρειας |
| Νομαρχιακό Συμβούλιο |
| Ενδιαφερόμενο Κοινό |
| Εδαφοτεχνικός Μελετητης |
| Συγκοινωνιλόγος Μηχανικός |
| Κύριος του Έργου |
| Γενικός Μελετητής(Ειδικός Συγκοινωνιολόγος) |
| Μελετήτής Οικονομολόγος |
| Δνση Χωροταξίας ΥΠΕΧΩΔΕ ή ΓΓ Περίφέρειας |
| ΥΠΕΧΩΔΕ |
| Ηλεκτρολόγος-Μηχανολόγος |
| ΓΕΜ |
| ΥΠΕΣΔΔΑ |
| Συναρμόδιες Υπηρεσίες |
| ΕΥΠΕ/ΥΠΕΧΩΔΕ ή ΔΙΠΕΧΩ ΓΓ Περιφέρειας |
| Συναρμόδιοι Υπουργοί |
| ΥΕΝ |
| Συναρμόδια Υπουργεία |

## Schedule

| ID | WBS | Task | Type | Duration | Start | Finish | Predecessors | Baseline start | Baseline finish | Baseline duration | Total slack | Free slack | Constraint | Resources | Work | Text1 |
| --- | --- | --- | --- | --- | --- | --- | --- | --- | --- | --- | --- | --- | --- | --- | --- | --- |
| 1 | 1 | Μελέτες Γενικού σχεδιασμού - Εκθέσεις για την Τεκμηρίωση Αναγκαιότητας του Έργου |  | 58d | 2002-01-01 | 2002-02-28 |  | 2002-01-01 | 2002-02-28 | 58d | 0d |  |  | Μελετητής | 1392h | 2Μ |
| 2 | 2 | **Διαδικασία Επιλογής Mελετητή** |  | 153d | 2002-02-28 | 2002-07-31 | 1 | 2002-01-11 | 2002-01-11 | 0.33d? | 0d |  |  | Εργοδότης | 8448h | 5Μ |
| 3 | 2.1 | Δημοσίευση Προκήρυξης Μελέτης |  | 45d | 2002-02-28 | 2002-04-14 |  | 2002-01-11 | 2002-01-11 | 0.33d? | 0d |  |  | Εργοδότης | 1080h | 1.5Μ |
| 4 | 2.2 | Αξιολόγηση Υποψήφιων μελετητών |  | 31d | 2002-04-14 | 2002-05-15 | 3 | 2002-04-14 | 2002-05-15 | 31d | 0d |  |  | Εργοδότης | 744h | 1Μ |
| 5 | 2.3 | Επιλογή Μελετητή |  | 15d | 2002-05-15 | 2002-05-30 | 4 | 2002-05-15 | 2002-05-30 | 15d | 0d |  |  | Εργοδότης | 360h | 0.5Μ |
| 6 | 2.4 | Κοινοποίηση Απόφασης Ανάθεσης |  | 16d | 2002-05-30 | 2002-06-15 | 5 | 2002-05-30 | 2002-06-15 | 16d | 0d |  |  | Εργοδότης | 384h | 0.5Μ |
| 7 | 2.5 | Διαδικασία Ενστάσεων |  | 46d | 2002-06-15 | 2002-07-31 | 6 | 2002-06-15 | 2002-08-31 | 77d | 0d |  |  | Εργοδότης; ΓΕΜ | 2208h | 1.5Μ |
| 8 | 2.6 | Ανάθεση Μελέτης | milestone | 0d | 2002-07-31 | 2002-07-31 | 7 | 2002-08-31 | 2002-08-31 | 0d? | 0d |  |  | Εργοδότης |  | 0Μ |
| 9 | 3 | Κατάρτιση Σύμβασης - Υπογραφή Σύμβασης - Εγκατάσταση Αναδόχου |  | 30d | 2002-07-31 | 2002-08-30 | 8 | 2002-08-31 | 2002-10-01 | 31d | 0d |  |  | Εργοδότης; Προιστάμενη Αρχή; Διευθύνουσα Υπηρεσία; Γενικός Μελετητής | 2880h | 1Μ |
| 10 | 4 | Επίβλεψη Μελέτης |  | 793d | 2002-08-30 | 2004-10-31 | 9 | 2002-10-01 | 2004-06-30 | 638d | 0d |  |  | Διευθύνουσα Υπηρεσία; Γενικός Μελετητής | 38064h | 26Μ |
| 11 | 5 | Εποπτεία Μελέτης |  | 793d | 2002-08-30 | 2004-10-31 | 10SS | 2002-10-01 | 2004-06-30 | 638d | 0d |  |  | Προιστάμενη Αρχή; Γενικός Μελετητής | 38064h | 26Μ |
| 12 | 6 | **ΣΤΑΔΙΟ Ι: Προκαταρκτική Μελέτη Έργου / Προμελέτη Περιβαλλοντικών Επιπτώσεων** |  | 182d | 2002-08-30 | 2003-02-28 | 11SS | 2002-10-01 | 2003-02-28 | 150d | 0d |  |  |  | 18576h | 6Μ |
| 13 | 6.1 | Μέτρηση Παροχών - Έλεγχος Καταλληλότητας Νερού |  | 60d | 2002-08-30 | 2002-10-29 |  | 2002-10-01 | 2002-11-30 | 60d | 824d |  |  | Μελετητής; Διευθύνουσα Υπηρεσία; Γενικός Μελετητής | 4320h | 2Μ |
| 14 | 6.2 | Προκαταρκτική μελέτη |  | 123d | 2002-08-30 | 2002-12-31 |  | 2002-10-01 | 2003-01-31 | 122d | 0d |  |  | Διευθύνουσα Υπηρεσία; Γενικός Μελετητής | 5904h | 4Μ |
| 15 | 6.3 | Υδρολογική Μελέτη |  | 61d | 2002-11-01 | 2003-01-01 |  | 2002-11-01 | 2003-01-01 | 61d | 760.33d |  | start no earlier than 2002-11-01 | Διευθύνουσα Υπηρεσία; Γενικός Μελετητής | 2928h | 2Μ |
| 16 | 6.4 | Γεωλογική Αναγνώριση |  | 61d | 2002-11-01 | 2003-01-01 |  | 2002-11-01 | 2003-01-01 | 61d | 761.33d |  | start no earlier than 2002-11-01 | Διευθύνουσα Υπηρεσία; Γενικός Μελετητής | 2928h | 2Μ |
| 17 | 6.5 | Εκπόνηση Προμελέτης Περιβαλλοντικών Επιπτώσεων - Π.Π.Ε (Φ.Π.Χ.) - Υποβολή |  | 30d | 2002-12-31 | 2003-01-30 | 14 | 2003-01-31 | 2003-02-28 | 28d | 0d |  |  | Διευθύνουσα Υπηρεσία; Γενικός Μελετητής | 1440h | 1Μ |
| 18 | 6.6 | **Διαδικασία Έκδοσης Προκαταρκτικής Περιβαλλοντικής Εκτίμησης και Αξιολόγησης (Π. Χ.)** |  | 29d | 2003-01-30 | 2003-02-28 | 17 | 2003-02-28 | 2003-03-31 | 31d | 0d |  |  | Εργοδότης | 1056h | 1Μ |
| 19 | 6.6.1 | Παραλαβή Π.Π.Ε (Φ.Π.Χ.) - Έλεγχος - Υποβολή |  | 7d | 2003-01-30 | 2003-02-06 |  | 2003-02-28 | 2003-03-05 | 5d | 0d |  |  | Διευθύνουσα Υπηρεσία | 168h | 0.25Μ |
| 20 | 6.6.2 | Παραλαβή Π.Π.Ε. (Φ.Π.Χ.) - Γνωμοδοτήσεις Συναρμοδιών |  | 15d | 2003-02-06 | 2003-02-21 | 19 | 2003-03-05 | 2003-03-10 | 5d | 0d |  |  | Διευθύνουσα Υπηρεσία; Συναρμόδιες Υπηρεσίες; ΕΥΠΕ/ΥΠΕΧΩΔΕ ή ΔΙΠΕΧΩ ΓΓ Περιφέρειας | 152h | 0.5Μ |
| 21 | 6.6.3 | Έκδοση Προκαταρκτικής Περιβαλλοντικής Εκτίμησης και Αξιολόγησης (Π. Χ.) |  | 7d | 2003-02-21 | 2003-02-28 | 20 | 2003-03-25 | 2003-03-31 | 6d | 0d |  |  | ΕΥΠΕ/ΥΠΕΧΩΔΕ ή ΔΙΠΕΧΩ ΓΓ Περιφέρειας | 40h | 0.25Μ |
| 22 | 7 | Έγκριση Σταδίου Ι |  | 31d | 2003-02-28 | 2003-03-31 | 18 | 2003-03-31 | 2003-04-30 | 30d | 0d |  |  | Εργοδότης | 744h | 1Μ |
| 23 | 8 | **ΣΤΑΔΙΟ ΙΙ: Προμελέτη Έργου / Μελέτη Περιβαλλοντικών Επιπτώσεων** |  | 275d | 2003-03-31 | 2003-12-31 | 22 | 2003-03-31 | 2003-12-31 | 275d | 0d |  |  |  | 39224h | 9Μ |
| 24 | 8.1 | **Μελέτες Υποστήριξης** |  | 275d | 2003-03-31 | 2003-12-31 |  | 2003-03-31 | 2003-12-31 | 275d | 0d |  |  |  | 20400h | 2Μ |
| 25 | 8.1.1 | Υδρολογική Μελέτη |  | 60d | 2003-03-31 | 2003-05-30 |  | 2003-03-31 | 2003-05-30 | 60d | 306d |  |  | Διευθύνουσα Υπηρεσία; Γενικός Μελετητής | 2880h | 2Μ |
| 26 | 8.1.2 | Γεωλογική Μελέτη |  | 60d | 2003-03-31 | 2003-05-30 |  | 2003-03-31 | 2003-05-30 | 60d | 306d |  |  | Διευθύνουσα Υπηρεσία; Γενικός Μελετητής; Γεωλόγος | 4320h | 2Μ |
| 27 | 8.1.3 | Οριοθέτηση Ρέματος - Τοπογραφική Αποτύπωση |  | 275d | 2003-03-31 | 2003-12-31 |  | 2003-03-31 | 2003-12-31 | 275d | 0d |  |  | Διευθύνουσα Υπηρεσία; Τοπογράφος | 13200h | 9Μ |
| 28 | 8.2 | Προμελέτη |  | 244d | 2003-03-31 | 2003-11-30 |  | 2003-03-31 | 2003-11-30 | 244d | 31d | 0d |  | Διευθύνουσα Υπηρεσία; Γενικός Μελετητής | 11712h | 8Μ |
| 29 | 8.3 | Εκπόνηση Μελέτης Περιβαλλοντικών Επιπτώσεων |  | 91d | 2003-03-31 | 2003-06-30 | 28SS | 2003-08-28 | 2003-11-26 | 90d | 44d | 0d |  | Διευθύνουσα Υπηρεσία; Γενικός Μελετητής | 4368h | 3Μ |

| ID | WBS | Task | Type | Duration | Start | Finish | Predecessors | Baseline start | Baseline finish | Baseline duration | Total slack | Free slack | Constraint | Resources | Work | Text1 |
| --- | --- | --- | --- | --- | --- | --- | --- | --- | --- | --- | --- | --- | --- | --- | --- | --- |
| 30 | 8.4 | **Έγκριση Μελέτης Περιβαλλοντικών Επιπτώσεων** |  | 137d | 2003-06-30 | 2003-11-14 | 29 | 2003-11-26 | 2004-03-31 | 126d | 44d |  |  |  | 2744h | 4.5M |
| 31 | 8.4.1 | Παραλαβή ΜΠΕ-Έλεγχος-Υποβολή |  | 15d | 2003-06-30 | 2003-07-15 |  | 2003-11-26 | 2003-12-11 | 15d | 44d | 0d |  | Διευθύνουσα Υπηρεσία | 360h | 0.5Μ |
| 32 | 8.4.2 | Παραλαβή της ΜΠΕ-Έλεγχος-Διαβίβαση |  | 16d | 2003-07-15 | 2003-07-31 | 31 | 2003-12-11 | 2004-01-10 | 30d | 44d | 0d |  | ΕΥΠΕ/ΥΠΕΧΩΔΕ ή ΔΙΠΕΧΩ ΓΓ Περιφέρειας | 96h | 0.5Μ |
| 33 | 8.4.3 | Παραλαβή της ΜΠΕ-Γνωμοδότηση-Διαβίβαση |  | 15d | 2003-07-31 | 2003-08-15 | 32 | 2003-12-26 | 2004-01-10 | 15d | 138d |  |  | Συναρμόδια Υπουργεία | 88h | 0.5Μ |
| 34 | 8.4.4 | Νομαρχιακό Συμβούλιο: Παραλαβή-Δημοσίευση Ανάρτηση ΜΠΕ |  | 15d | 2003-07-31 | 2003-08-15 | 32 | 2004-01-10 | 2004-02-09 | 30d | 45d | 0d |  | Νομαρχιακό Συμβούλιο | 360h | 0.5Μ |
| 35 | 8.4.5 | Διατύπωση Απόψεων - Αντιρρήσεων - Προτάσεων |  | 15d | 2003-08-15 | 2003-08-30 | 34 | 2004-01-25 | 2004-02-14 | 20d | 45d | 0d |  | Ενδιαφερόμενο Κοινό | 360h | 0.5Μ |
| 36 | 8.4.6 | Νομαρχιακό Συμβούλιο: Κριτική Άποψη Διαβίβαση |  | 15d | 2003-08-30 | 2003-09-14 | 35 | 2004-02-14 | 2004-02-29 | 15d | 45d | 0d |  | Νομαρχιακό Συμβούλιο | 360h | 0.5Μ |
| 37 | 8.4.7 | Σύνταξη Σχεδίου Απόφασης Έγκρισης Περιβαλλοντικών Όρων |  | 30d | 2003-09-14 | 2003-10-14 | 36 | 2004-02-29 | 2004-03-15 | 15d | 45d | 0d |  | ΕΥΠΕ/ΥΠΕΧΩΔΕ ή ΔΙΠΕΧΩ ΓΓ Περιφέρειας | 168h | 1Μ |
| 38 | 8.4.8 | Υπογραφή Υπουργών ή Γ.Γ. Περιφέρειας |  | 16d | 2003-10-14 | 2003-10-30 | 37 | 2004-03-15 | 2004-03-31 | 16d | 45d | 0d |  | ΥΠΕΧΩΔΕ; ΓΓ Περίφέρειας; Συναρμόδιοι Υπουργοί | 864h | 0.5Μ |
| 39 | 8.4.9 | Έκδοση Απόφασης Έγκρισης Περιβαλλοντικών Όρων | milestone | 15d | 2003-10-30 | 2003-11-14 | 38 | 2004-03-31 | 2004-03-31 | 15d | 47d |  |  | ΕΥΠΕ/ΥΠΕΧΩΔΕ ή ΔΙΠΕΧΩ ΓΓ Περιφέρειας | 88h | 0.5Μ |
| 40 | 9 | Έγκριση Σταδίου ΙΙ |  | 31d | 2003-11-30 | 2003-12-31 | 23FF | 2003-11-30 | 2003-12-31 | 31d | 0d |  |  | Εργοδότης | 744h | 1Μ |
| 41 | 10 | Γεωλογικές και Γεωτεχνικές Έρευνες |  | 212d | 2003-05-01 | 2003-11-29 | 23SS+31d | 2003-05-01 | 2003-11-29 | 212d | 429d |  |  | Διευθύνουσα Υπηρεσία; Γεωλόγος; Γεωτεχνικός | 15264h | 7Μ |
| 42 | 11 | **ΣΤΑΔΙΟ ΙΙΙ: Οριστική Μελέτη Έργου** |  | 213d | 2003-12-31 | 2004-07-31 | 40 | 2003-04-30 | 2003-12-31 | 245d | 0d |  |  |  | 12360h | 7Μ |
| 43 | 11.1 | **Μελέτες Υποστήριξης** |  | 60d | 2003-12-31 | 2004-02-29 |  | 2003-04-30 | 2003-06-29 | 60d | 0d |  |  |  | 5760h | 2Μ |
| 44 | 11.1.1 | Γεωλογική - Γεωτεχνική Μελέτη |  | 60d | 2003-12-31 | 2004-02-29 |  | 2003-04-30 | 2003-06-29 | 60d | 336d |  |  | Διευθύνουσα Υπηρεσία; Γενικός Μελετητής | 2880h | 2Μ |
| 45 | 11.1.2 | Τοπογραφική μελέτη |  | 60d | 2003-12-31 | 2004-02-29 |  | 2003-04-30 | 2003-06-29 | 60d | 0d |  |  | Διευθύνουσα Υπηρεσία; Γενικός Μελετητής | 2880h | 2Μ |
| 46 | 11.2 | Οριστική Μελέτη |  | 122d | 2004-02-29 | 2004-06-30 | 45 | 2003-06-29 | 2003-11-29 | 153d | 0d |  | start no earlier than 2003-04-27 | Διευθύνουσα Υπηρεσία; Γενικός Μελετητής | 5856h | 4Μ |
| 47 | 11.3 | Έγκριση Σταδίου ΙΙΙ |  | 31d | 2004-06-30 | 2004-07-31 | 46 | 2004-02-29 | 2004-03-31 | 31d | 0d |  |  | Εργοδότης | 744h | 1Μ |
| 48 | 12 | **ΣΤΑΔΙΟ IV: Λοιπές Ενέργειες** |  | 367d | 2003-10-30 | 2004-10-31 | 47FS-275d | 2003-03-31 | 2004-06-30 | 457d | 0d |  |  |  | 28608h | 15Μ |
| 49 | 12.1 | Κτηματολόγιο |  | 336d | 2003-10-30 | 2004-09-30 |  | 2003-03-31 | 2004-02-29 | 335d | 123d |  |  | Διευθύνουσα Υπηρεσία; Γενικός Μελετητής; Τοπογράφος | 24192h | 11Μ |
| 50 | 12.2 | Απαλλοτριώσεις |  | 92d | 2004-07-31 | 2004-10-31 | 47 | 2003-12-31 | 2004-06-30 | 182d | 0d |  |  |  |  | 3Μ |
| 51 | 12.3 | Σύνταξη και Έγκριση Τευχών Δημοπράτησης |  | 92d | 2004-07-31 | 2004-10-31 | 50SS | 2003-12-31 | 2004-03-31 | 91d | 0d |  |  | Διευθύνουσα Υπηρεσία; Γενικός Μελετητής | 4416h | 3Μ |
