# εσωτερικα δικτυα

Schedule from MS Project, 2002-01-01 to 2003-08-31, 24 hours a day.
NAMA SA

## Calendars

- 24 Hours: Mon-Sun 00:00-24:00.

## Resources

| Resource |
| --- |
| Εργοδότης |
| Προιστάμενη Αρχή |
| Διευθύνουσα Υπηρεσία |
| Γενικός Μελετητής |
| Αλλοι τοπικοί φορείς |
| Μελετητές |
| Γεωλόγος |
| Δνση Χωροταξίας ΥΠΕΧΩΔΕ |
| ΓΓ Περίφέρειας |
| Δνση Χωροταξίας (Κεντρική ή Περιφερειακή) |
| Υπουργείο Γεωργείας |
| ΥΠΠΟ |
| ΥΠΕΧΩΔΕ/Περιβάλλον |
| Τοπογράφος |
| Γεωτεχνικός |
| Κυκλοφοριολόγος |
| Μελετητης Περιβαλλοντολόγος |
| Δνση Περιβαλλοντικού Σχεδιασμού |
| Δνση Περιβαλλοντος και Χωροταξίας Γενικής Γραμματείας της Περιφέρειας |
| Νομαρχιακό Συμβούλιο |
| Ενδιαφερόμενο Κοινό |
| Εδαφοτεχνικός Μελετητης |
| Συγκοινωνιλόγος Μηχανικός |
| Κύριος του Έργου |
| Γενικός Μελετητής(Ειδικός Συγκοινωνιολόγος) |
| Μελετήτής Οικονομολόγος |
| Δνση Χωροταξίας ΥΠΕΧΩΔΕ ή ΓΓ Περίφέρειας |
| ΥΠΕΧΩΔΕ |
| Ηλεκτρολόγος-Μηχανολόγος |
| ΓΕΜ |
| Στατικός |
| Περιβαλλοντολόγος |

## Schedule

| ID | WBS | Task | Type | Duration | Start | Finish | Predecessors | Baseline start | Baseline finish | Baseline duration | Total slack | Free slack | Resources | Work | Text1 |
| --- | --- | --- | --- | --- | --- | --- | --- | --- | --- | --- | --- | --- | --- | --- | --- |
| 1 | 1 | Μελέτες Γενικού σχεδιασμού - Εκθέσεις για την Τεκμηρίωση Αναγκαιότητας του Έργου |  | 58d | 2002-01-01 | 2002-02-28 |  | 2002-01-01 | 2002-02-28 | 58d | 0.67d | 0d | Γενικός Μελετητής | 1392h | 2Μ |
| 2 | 2 | **Διαδικασία Επιλογής μελετητή** |  | 153d | 2002-02-28 | 2002-07-31 | 1 | 2002-01-11 | 2002-01-11 | 0.33d? | 0.67d |  | Εργοδότης | 8448h | 5Μ |
| 3 | 2.1 | Δημοσίευση Προκήρυξης Μελέτης |  | 45d | 2002-02-28 | 2002-04-14 |  | 2002-01-11 | 2002-01-11 | 0.33d? | 0.67d | 0d | Εργοδότης | 1080h | 1.5Μ |
| 4 | 2.2 | Αξιολόγηση Υποψήφιων Μελετητών |  | 31d | 2002-04-14 | 2002-05-15 | 3 | 2002-04-14 | 2002-05-15 | 31d | 0.67d | 0d | Εργοδότης | 744h | 1Μ |
| 5 | 2.3 | Επιλογή Μελετητή |  | 15d | 2002-05-15 | 2002-05-30 | 4 | 2002-05-15 | 2002-05-30 | 15d | 0.67d | 0d | Εργοδότης | 360h | 0.5Μ |
| 6 | 2.4 | Κοινοποίηση Απόφασης Ανάθεσης |  | 16d | 2002-05-30 | 2002-06-15 | 5 | 2002-05-30 | 2002-06-15 | 16d | 0.67d | 0d | Εργοδότης | 384h | 0.5Μ |
| 7 | 2.5 | Διαδικασία Ενστάσεων |  | 46d | 2002-06-15 | 2002-07-31 | 6 | 2002-06-15 | 2002-08-31 | 77d | 0.67d | 0d | Εργοδότης; ΓΕΜ | 2208h | 1.5Μ |
| 8 | 2.6 | Ανάθεση Μελέτης | milestone | 0d | 2002-07-31 | 2002-07-31 | 7 | 2002-08-31 | 2002-08-31 | 0d? | 0.67d | 0d | Εργοδότης |  | 0Μ |
| 9 | 3 | Κατάρτιση Σύμβασης - Υπογραφή Σύμβασης - Εγκατάσταση Αναδόχου |  | 31d | 2002-07-31 | 2002-08-31 | 8 | 2002-08-31 | 2002-10-01 | 31d | 0.67d | 0d | Εργοδότης; Προιστάμενη Αρχή; Διευθύνουσα Υπηρεσία; Γενικός Μελετητής | 2976h | 1Μ |
| 10 | 4 | Εκπόνηση και Έγκριση Πολεοδομικού Σχεδιασμού | milestone | 0d | 2002-08-31 | 2002-08-31 | 9 | 2002-10-01 | 2002-10-01 | 0d? | 0.67d | 0d |  |  | 0Μ |
| 11 | 5 | Σύνταξη και Έγκριση Χωροταξικής Μελέτης | milestone | 0d | 2002-08-31 | 2002-08-31 | 10 | 2002-10-01 | 2002-10-01 | 0d? | 0.67d | 0d |  |  | 0Μ |
| 12 | 6 | Επίβλεψη Μελέτης |  | 364d | 2002-08-31 | 2003-08-30 | 11 | 2002-10-01 | 2003-01-09 | 100d | 0.67d | 0d | Διευθύνουσα Υπηρεσία; Γενικός Μελετητής | 17472h | 12Μ |
| 13 | 7 | Εποπτεία Μελέτης |  | 364d | 2002-08-31 | 2003-08-30 | 12SS | 2002-10-01 | 2003-01-09 | 100d | 0.67d | 0d | Προιστάμενη Αρχή; Γενικός Μελετητής | 17472h | 12Μ |
| 14 | 8 | **ΣΤΑΔΙΟ Ι: Προκαταρκτική Μελέτη Έργου** |  | 122d | 2002-08-31 | 2002-12-31 | 13SS | 2002-10-01 | 2003-01-31 | 122d | 61.67d | 0d |  | 15200h | 4Μ |
| 15 | 8.1 | Στρατηγικό Μαθηματικό Μοντέλο Βελτιστοποίησης |  | 60d | 2002-08-31 | 2002-10-30 |  | 2002-10-01 | 2002-11-30 | 60d | 153d |  | Διευθύνουσα Υπηρεσία; Γενικός Μελετητής | 2880h | 1Μ |
| 16 | 8.2 | Προκαταρκτική μελέτη |  | 91d | 2002-08-31 | 2002-11-30 |  | 2002-10-01 | 2002-12-31 | 91d | 91d | 0d | Διευθύνουσα Υπηρεσία; Γενικός Μελετητής | 4368h | 3Μ |
| 17 | 8.3 | Διερεύνηση Δικτύων Ο.Κ.Ω |  | 91d | 2002-08-31 | 2002-11-30 |  | 2002-10-01 | 2002-12-31 | 91d | 122d |  | Διευθύνουσα Υπηρεσία; Γενικός Μελετητής | 4368h | 3Μ |
| 18 | 8.4 | Οικονομοτεχνική Μελέτη |  | 30d | 2002-10-31 | 2002-11-30 | 16FF | 2002-11-30 | 2002-12-31 | 31d | 92.67d |  | Διευθύνουσα Υπηρεσία; Γενικός Μελετητής | 1440h | 1Μ |
| 19 | 8.5 | Περιβαλλοντική Θεώρηση |  | 30d | 2002-10-31 | 2002-11-30 | 16FF | 2002-11-30 | 2002-12-31 | 31d | 61.67d | 0d | Διευθύνουσα Υπηρεσία; Περιβαλλοντολόγος | 656h | 1Μ |
| 20 | 8.6 | Απαλλαγή απο τη Διαδικασία Περιβαλλοντικής Αδειοδότησης |  | 31d | 2002-11-30 | 2002-12-31 | 19 | 2002-12-31 | 2003-01-31 | 31d | 91d |  | Διευθύνουσα Υπηρεσία; Γενικός Μελετητής | 1488h | 1Μ |
| 21 | 9 | Έγκριση Σταδίου Ι |  | 31d | 2002-12-31 | 2003-01-31 | 14 | 2003-01-31 | 2003-02-28 | 28d | 91d | 0d | Εργοδότης | 744h | 1Μ |
| 22 | 10 | **ΣΤΑΔΙΟ ΙΙ: Οριστικές Μελέτες Έργων** |  | 240d | 2002-10-03 | 2003-05-31 | 21FS-120d | 2002-10-31 | 2003-07-01 | 242.67d | 61.67d | 0d |  | 29608h | 8Μ |
| 23 | 10.1 | **Οριστικές Μελέτες** |  | 120d | 2003-01-31 | 2003-05-31 | 21 | 2003-03-01 | 2003-07-01 | 122d | 61.67d | 0d |  | 13672h | 4Μ |
| 24 | 10.1.1 | Υδραυλική Μελέτη |  | 120d | 2003-01-31 | 2003-05-31 |  | 2003-03-01 | 2003-07-01 | 122d | 92.67d |  | Διευθύνουσα Υπηρεσία; Γενικός Μελετητής | 5760h | 4Μ |
| 25 | 10.1.2 | Στατική Μελέτη |  | 120d | 2003-01-31 | 2003-05-31 |  | 2003-03-01 | 2003-07-01 | 122d | 91d |  | Διευθύνουσα Υπηρεσία; Στατικός | 2152h | 4Μ |
| 26 | 10.1.3 | Η/Μ Μελέτη |  | 120d | 2003-01-31 | 2003-05-31 |  | 2003-03-01 | 2003-07-01 | 122d | 92.67d |  | Διευθύνουσα Υπηρεσία; Ηλεκτρολόγος-Μηχανολόγος | 5760h | 4Μ |

| ID | WBS | Task | Duration | Start | Finish | Predecessors | Baseline start | Baseline finish | Baseline duration | Total slack | Free slack | Constraint | Resources | Work | Text1 |
| --- | --- | --- | --- | --- | --- | --- | --- | --- | --- | --- | --- | --- | --- | --- | --- |
| 27 | 10.2 | **Μελέτες Υποστήριξης** | 61d | 2003-02-28 | 2003-04-30 | 23SS+28d | 2003-04-01 | 2003-06-01 | 61d | 92.67d |  |  |  | 5856h | 2Μ |
| 28 | 10.2.1 | Γεωτεχνική Μελέτη | 61d | 2003-02-28 | 2003-04-30 |  | 2003-04-01 | 2003-06-01 | 61d | 123.67d |  |  | Διευθύνουσα Υπηρεσία; Γεωτεχνικός | 2928h | 2Μ |
| 29 | 10.2.2 | Τοπογραφική Μελέτη | 61d | 2003-02-28 | 2003-04-30 |  | 2003-04-01 | 2003-06-01 | 61d | 123.67d |  |  | Διευθύνουσα Υπηρεσία; Τοπογράφος | 2928h | 2Μ |
| 30 | 10.3 | Χαρτογράφηση GIS | 120d | 2002-10-03 | 2003-01-31 |  | 2002-10-31 | 2003-06-30 | 242d | 212.67d |  |  | Διευθύνουσα Υπηρεσία; Γενικός Μελετητής | 5760h | 4Μ |
| 31 | 10.4 | Καταγραφή Δικτύων Ο.Κ.Ω | 90d | 2003-02-01 | 2003-05-02 |  | 2003-03-01 | 2003-07-01 | 122d | 122d |  | start no earlier than 2003-02-01 | Διευθύνουσα Υπηρεσία; Γενικός Μελετητής | 4320h | 3Μ |
| 32 | 11 | Εγκριση Σταδίου ΙΙ | 30d | 2003-05-31 | 2003-06-30 | 22 | 2003-07-01 | 2003-08-01 | 31d | 92.67d | 0d | start no earlier than 2003-05-31 | Εργοδότης | 720h | 1Μ |
| 33 | 12 | **ΣΤΑΔΙΟ ΙΙΙ: Λοιπές Ενέργειες** | 183.67d | 2003-02-28 | 2003-08-31 | 32FS-122d | 2003-04-01 | 2003-12-01 | 244d | 0d |  |  |  | 8760h | 8Μ |
| 34 | 12.1 | Κτηματολόγιο | 61d | 2003-02-28 | 2003-04-30 |  | 2003-04-01 | 2003-05-31 | 60d | 183.67d |  |  | Διευθύνουσα Υπηρεσία; Γενικός Μελετητής; Τοπογράφος | 4392h | 2Μ |
| 35 | 12.2 | Απαλλοτριώσεις | 61d | 2003-06-01 | 2003-08-01 |  | 2003-07-01 | 2003-09-01 | 62d | 30d |  | start no earlier than 2003-06-01 |  |  | 2Μ |
| 36 | 12.3 | Σύνταξη και Έγκριση των Τευχών Δημοπράτησης | 91d | 2003-06-01 | 2003-08-31 |  | 2003-07-01 | 2003-09-01 | 62d | 0d |  | start no earlier than 2003-06-01 | Διευθύνουσα Υπηρεσία; Γενικός Μελετητής | 4368h | 3M |
