Schedule from MS Project, 2002-01-01 to 2005-04-02, 24 hours a day.
NAMA SA

## Calendars

- 24 Hours: Mon-Sun 00:00-24:00.

## Resources

| Resource |
| --- |
| Εργοδότης |
| Προιστάμενη Αρχή |
| Διευθύνουσα Υπηρεσία |
| Γενικός Μελετητής |
| Αλλοι τοπικοί φορείς |
| Δνση Χωροταξίας ΥΠΕΧΩΔΕ |
| ΓΓ Περίφέρειας |
| ΥΠΕΧΩΔΕ/Περιβάλλον |
| Μελετητης Περιβαλλοντολόγος |
| Δνση Περιβαλλοντικού Σχεδιασμού ΥΠΕΧΩΔΕ |
| Δνση Περιβαλλοντος και Χωροταξίας Γενικής Γραμματείας της Περιφέρειας |
| Ενδιαφερόμενο Κοινό |
| Κύριος του Έργου |
| Συναρμόδιες Υπηρεσίες |
| Δ/νση Υγιεινής-Δνση Περιβάλλοντος-Δνση Τεχνικών Υπηρεσιών Νομαρχίας |
| Εμπλεκόμενοι Δήμοι ή Κοινότητες |
| Άμεσα ενδιαφερόμενες Υπηρεσίες |
| Φορέας υλοποίησης του έργου |
| Δ.Σ. της ΔΕΥΑ |
| ΤΥΔΚ Περιφέρειας |
| Τμήμα Πρωτοβ.Τοπικής Υπηρεσίας Περιφέρειας |
| ΓΕΜ |
| Τεχνική Υπηρεσία ΟΤΑ ή ΔΕΥΑ ή ΤΥΔΚ |
| Εφορείες αρχαιοτήτων |
| Δασική Υπηρεσία |
| ΝΕΧΩΠ |
| ΕΥΠΕ/ΥΠΕΧΩΔΕ ή ΔΙΠΕΧΩ Περιφέρειας |
| Οργανισμός Αθήνας/ Θεσσαλονίκης |
| ΔΙ.ΠΕ.ΧΩ. Περιφέρειας |
| Δ/νσεις Περιβάλλοντος των Νομαρχιακών Διαμερισμάτων της ΝΑ Αττικής |
| Αρμόδιες ΔΟΥ |
| Αρμόδια Μονομέλή Πρωτοδικεία Νομών |
| Τεχν. Υπηρ. Δήμου ή Κοινότητας ή της ΔΕΥΑ |
| Δ/νση Τεχν. Υπηρ. Του ΥΠ.ΕΣ.Δ.Δ.Α |
| ΔΤΥ ΥΠ.ΕΣ.Δ.Δ.Α |
| ΔΥΠ |
| Δ/νση Πολεοδομικού Σχεδιασμού ΥΠΕΧΩΔΕ |
| Δ/νσεις Συναρμοδίων Υπουργείων |
| Δ/νση ΠΕ.ΧΩ. Τμήμα Περιβάλλοντος της Περιφέρειας |
| Νομαρχιακό Συμβούλιο |
| Αρμόδιες Υπηρεσίες χρηματοδοτήσεων (ΥΠ.ΕΘ.Ο. -ΥΠ.ΕΣ. - Περιφ.) |
| Επιτροπή Προεπιλογής Υποψήφιων Αναδόχων |
| Επιτροπή Παραλαβής προσφορών |
| Υποψήφιοι Ανάδοχοι του Έργου |
| Επιτροπή Εισήγησης για Ανάθεση |
| Ανάδοχος |
| Δνση Υγιεινής |
| ΔΤΥΝΑ Νομαρχίας |
| Δ/νση Πολεοδομίας της Ν.Α. |
| Τ. Υ. Δήμου ή Κοινότητας ή της ΔΕΥΑ |
| Τμήμα Πρωτοβα.Τοπικής Υπηρεσίας Περιφέρειας |
| Οργανισμός Αθήνας/Θεσσαλονίκης |
| Γεωλόγος |
| Γεωπόνος |
| Γεωτεχνικός |
| Στατικός |
| Μηχανολόγος |
| Τοπογράφος |
| Συγκοινωνιολόγος |
| ΥΠΠΟ |
| ΥΠΓΕ |
| Δ/νση Χωροταξίας (Κεντρική ή Περιφερειακή) |
| ΥΠΕΧΩΔΕ |
| Οικονομολόγος |
| Συναρμόδια Υπουργεία |

## Schedule

| ID | WBS | Task | Duration | Start | Finish | Predecessors | Total slack | Free slack | Constraint | Resources | Work | Text1 |
| --- | --- | --- | --- | --- | --- | --- | --- | --- | --- | --- | --- | --- |
| 1 | 1 | Μελέτες Γενικού Σχεδιασμού / Σκοπιμότητας του Έργου | 120d | 2002-01-01 | 2002-05-01 |  | 0d |  |  | Γενικός Μελετητής; Γεωλόγος; Γεωπόνος; Γεωτεχνικός | 11520h | 4Μ |
| 2 | 2 | Διαδικασία Επιλογής Μελετητή | 153d | 2002-05-01 | 2002-10-01 | 1 | 0d |  |  | Εργοδότης | 3672h | 5Μ |
| 3 | 3 | Κατάρτιση Σύμβασης-Υπογραφή Σύμβασης - Εγκατάσταση Αναδόχου | 30d | 2002-10-01 | 2002-10-31 | 2 | 0d |  |  | Εργοδότης; ΓΕΜ | 1440h | 1Μ |
| 4 | 4 | **ΣΤΑΔΙΟ Ι: Γενική Προκαταρκτική Μελέτη / Προμελέτη Περιβαλλοντικών Επιπτώσεων** | 211d | 2002-10-31 | 2003-05-30 | 3 | 0d |  |  |  | 35616h | 7Μ |
| 5 | 4.1 | Μετρήσεις Παροχών | 150d | 2002-10-31 | 2003-03-30 |  | 0d |  |  | Διευθύνουσα Υπηρεσία; Γενικός Μελετητής | 7200h | 25Μ |
| 6 | 4.2 | Προκαταρκτική Μελέτη | 91d | 2002-10-31 | 2003-01-30 | 5SS | 0d |  |  | Γενικός Μελετητής; Διευθύνουσα Υπηρεσία | 4368h | 3Μ |
| 7 | 4.3 | **Μελέτες Υποστήριξης** | 91d | 2002-10-31 | 2003-01-30 | 6SS | 0d |  |  |  | 13104h | 3Μ |
| 8 | 4.3.1 | Υδρολογική Μελέτη | 91d | 2002-10-31 | 2003-01-30 |  | 0d |  |  | Γενικός Μελετητής; Διευθύνουσα Υπηρεσία | 4368h | 3Μ |
| 9 | 4.3.2 | Γεωλογική Αναγνώριση | 91d | 2002-10-31 | 2003-01-30 |  | 0d |  |  | Γεωλόγος; Διευθύνουσα Υπηρεσία | 4368h | 3Μ |
| 10 | 4.3.3 | Υδρογεωλογική Προμελέτη | 91d | 2002-10-31 | 2003-01-30 |  | 0d |  |  | Διευθύνουσα Υπηρεσία; Γεωλόγος | 4368h | 3Μ |
| 11 | 4.4 | Εκπόνηση Προμελέτης Περιβαλλοντικών Επιπτώσεων - Π.Π.Ε. (Φ. Π. Χ.) | 90d | 2002-11-29 | 2003-02-27 | 7FS-62d | 0d |  |  | Διευθύνουσα Υπηρεσία; Γενικός Μελετητής | 4320h | 3Μ |
| 12 | 4.5 | Διαδικασία Έκδοσης Προκαταρκτικής Περιβαλλοντικής Εκτίμησης και Αξιολόγησης (Π.Χ.) | 92d | 2003-02-27 | 2003-05-30 | 11 | 0d |  |  | Διευθύνουσα Υπηρεσία; ΕΥΠΕ/ΥΠΕΧΩΔΕ ή ΔΙΠΕΧΩ Περιφέρειας; Συναρμόδιες Υπηρεσίες | 6624h | 3Μ |
| 13 | 5 | Έγκριση Σταδίου Ι | 31d | 2003-05-30 | 2003-06-30 | 12 | 0d |  |  | Εργοδότης | 744h | 1Μ |
| 14 | 6 | **Στάδιο ΙΙ: Προμελέτες Έργων/ Μελέτη Περιβαλλοντικών Επιπτώσεων** | 489d | 2003-06-30 | 2004-10-31 | 13 | 0d |  |  |  | 89920h | 16Μ |
| 15 | 6.1 | Οικονομοτεχνική Μελέτη και Αξιολόγηση | 60d | 2004-07-02 | 2004-08-31 | 17FF | 61d |  |  | Διευθύνουσα Υπηρεσία; Οικονομολόγος | 1776h | 2Μ |
| 16 | 6.2 | Ερευνες (Γεωλογικές - Γεωφυσικές -Γεωτεχνικές) | 120d | 2003-10-31 | 2004-02-28 | 17SS+123d | 246d |  |  | Διευθύνουσα Υπηρεσία; Γεωλόγος | 5760h | 4Μ |
| 17 | 6.3 | Προμελέτη | 428d | 2003-06-30 | 2004-08-31 |  | 0d |  |  | Γενικός Μελετητής; Διευθύνουσα Υπηρεσία | 20544h | 14Μ |
| 18 | 6.4 | **Μελέτες Υποστήριξης** | 307d | 2003-06-30 | 2004-05-02 | 17SS | 182d |  |  |  | 32160h | 10Μ |
| 19 | 6.4.1 | Υδρολογική μελέτη | 152d | 2003-10-01 | 2004-03-01 |  | 244d |  | start no earlier than 2003-10-01 | Γενικός Μελετητής; Διευθύνουσα Υπηρεσία | 7296h | 5Μ |
| 20 | 6.4.2 | Γεωλογική - Υδρογεωλογική Μελέτη | 152d | 2003-10-01 | 2004-03-01 |  | 244d |  | start no earlier than 2003-10-01 | Γεωλόγος; Διευθύνουσα Υπηρεσία | 7296h | 5Μ |
| 21 | 6.4.3 | Γεωτεχνική Μελέτη | 122d | 2003-11-30 | 2004-03-31 |  | 246d |  | start no earlier than 2003-11-30 | Διευθύνουσα Υπηρεσία; Γεωτεχνικός | 5856h | 4Μ |
| 22 | 6.4.4 | Τοπογραφική Μελέτη | 153d | 2003-06-30 | 2003-11-30 |  | 336d |  |  | Τοπογράφος; Διευθύνουσα Υπηρεσία | 7344h | 5Μ |
| 23 | 6.4.5 | Σεισμική Επικινδυνότητα | 60d | 2004-03-01 | 2004-04-30 |  | 184d |  | start no earlier than 2004-03-01 | Γενικός Μελετητής; Διευθύνουσα Υπηρεσία | 2880h | 2Μ |
| 24 | 6.4.6 | Γεωργοτεχνική Μελέτη - Γεωργοοικονομική Μελέτη | 31d | 2004-04-01 | 2004-05-02 |  | 30d | 0d | start no earlier than 2004-04-01 | Διευθύνουσα Υπηρεσία; Γεωπόνος | 1488h | 1Μ |
| 25 | 6.5 | Έγκριση Α' Φάσης | 31d | 2004-08-31 | 2004-10-01 | 17 | 30d |  |  | Εργοδότης | 744h | 1Μ |
| 26 | 6.6 | Εκπόνηση Μελέτης Περιβαλλοντικών Επιπτώσεων | 213d | 2003-09-30 | 2004-04-30 | 17SS+92d | 0d |  |  | Μελετητης Περιβαλλοντολόγος; Διευθύνουσα Υπηρεσία | 10224h | 7Μ |
| 27 | 6.7 | Έγκριση Περιβαλλοντικών Όρων | 184d | 2004-04-30 | 2004-10-31 | 26 | 0d |  |  | Διευθύνουσα Υπηρεσία; Νομαρχιακό Συμβούλιο; ΕΥΠΕ/ΥΠΕΧΩΔΕ ή ΔΙΠΕΧΩ Περιφέρειας; ΓΓ Περίφέρειας; Συναρμόδια Υπουργεία | 18712h | 6Μ |
| 28 | 7 | Έγκριση Σταδίου ΙΙ | 31d | 2004-10-31 | 2004-12-01 | 14 | 0d |  |  | Εργοδότης | 744h | 1Μ |

| ID | WBS | Task | Duration | Start | Finish | Predecessors | Total slack | Free slack | Resources | Work | Text1 |
| --- | --- | --- | --- | --- | --- | --- | --- | --- | --- | --- | --- |
| 29 | 8 | **Στάδιο ΙΙΙ: Σύνταξη Τευχών Δημοπράτησης** | 60d | 2004-12-01 | 2005-01-30 | 28 | 0d |  |  | 2880h | 5Μ |
| 30 | 8.1 | Σύνταξη Τευχών Δημοπράτησης | 60d | 2004-12-01 | 2005-01-30 |  | 0d |  | Διευθύνουσα Υπηρεσία; Γενικός Μελετητής | 2880h | 2Μ |
| 31 | 9 | Έγκριση Σταδίου ΙΙΙ | 62d | 2005-01-30 | 2005-04-02 | 29 | 0d |  | Εργοδότης | 1488h | 2Μ |
| 32 | 10 | **Στάδιο ΙV: Λοιπές Εργασίες** | 333d | 2004-05-02 | 2005-03-31 |  | 2d |  |  | 23976h | 11Μ |
| 33 | 10.1 | Κτηματολόγιο | 333d | 2004-05-02 | 2005-03-31 | 24 | 2d | 0d | Διευθύνουσα Υπηρεσία; Γενικός Μελετητής; Τοπογράφος | 23976h | 11Μ |
| 34 | 10.2 | Απαλλοτριώσεις | 212d | 2004-08-31 | 2005-03-31 | 33FF | 2d |  |  |  | 7Μ |
