Schedule from MS Project, 2002-01-01 to 2004-11-02, 24 hours a day.
NAMA SA

## Calendars

- 24 Hours: Mon-Sun 00:00-24:00.

## Resources

| Resource |
| --- |
| Εργοδότης |
| Προιστάμενη Αρχή |
| Διευθύν. Υπηρεσία |
| Γενικός Μελετητής |
| Αλλοι τοπικοί φορείς |
| Δνση Χωροταξίας ΥΠΕΧΩΔΕ |
| ΓΓ Περίφέρειας |
| ΥΠΕΧΩΔΕ/Περιβάλλον |
| Μελετητης Περιβαλλοντολόγος |
| Δνση Περιβαλλοντικού Σχεδιασμού ΥΠΕΧΩΔΕ |
| Δνση Περιβαλλοντος και Χωροταξίας Γενικής Γραμματείας της Περιφέρειας |
| Ενδιαφερόμενο Κοινό |
| Κύριος του Έργου |
| Συναρμόδιες Υπηρεσίες |
| Δ/νση Υγιεινής-Δνση Περιβάλλοντος-Δνση Τεχνικών Υπηρεσιών Νομαρχίας |
| Εμπλεκόμενοι Δήμοι ή Κοινότητες |
| Άμεσα ενδιαφερόμενες Υπηρεσίες |
| Φορέας υλοποίησης του έργου |
| Δ.Σ. της ΔΕΥΑ |
| ΤΥΔΚ Περιφέρειας |
| Τμήμα Πρωτοβ.Τοπικής Υπηρεσίας Περιφέρειας |
| ΓΕΜ |
| Τεχνική Υπηρεσία ΟΤΑ ή ΔΕΥΑ ή ΤΥΔΚ |
| Εφορείες αρχαιοτήτων |
| Δασική Υπηρεσία |
| ΝΕΧΩΠ |
| ΕΥΠΕ/ΥΠΕΧΩΔΕ |
| Οργανισμός Αθήνας/ Θεσσαλονίκης |
| Δ/νσεις ΠΕ.ΧΩ. Περιφερειών |
| Δ/νσεις Περιβάλλοντος των Νομαρχιακών Διαμερισμάτων της ΝΑ Αττικής |
| Αρμόδιες ΔΟΥ |
| Αρμόδια Μονομέλή Πρωτοδικεία Νομών |
| Τεχν. Υπηρ. Δήμου ή Κοινότητας ή της ΔΕΥΑ |
| Δ/νση Τεχν. Υπηρ. Του ΥΠ.ΕΣ.Δ.Δ.Α |
| ΔΤΥ ΥΠ.ΕΣ.Δ.Δ.Α |
| ΔΥΠ |
| Δ/νση Πολεοδομικού Σχεδιασμού ΥΠΕΧΩΔΕ |
| Δ/νσεις Συναρμοδίων Υπουργείων |
| Δ/νση ΠΕ.ΧΩ. Τμήμα Περιβάλλοντος της Περιφέρειας |
| Νομαρχιακό Συμβούλιο |
| Αρμόδιες Υπηρεσίες χρηματοδοτήσεων (ΥΠ.ΕΘ.Ο. -ΥΠ.ΕΣ. - Περιφ.) |
| Επιτροπή Προεπιλογής Υποψήφιων Αναδόχων |
| Επιτροπή Παραλαβής προσφορών |
| Υποψήφιοι Ανάδοχοι του Έργου |
| Επιτροπή Εισήγησης για Ανάθεση |
| Ανάδοχος |
| Δνση Υγιεινής |
| ΔΤΥΝΑ Νομαρχίας |
| Δ/νση Πολεοδομίας της Ν.Α. |
| Τ. Υ. Δήμου ή Κοινότητας ή της ΔΕΥΑ |
| Τμήμα Πρωτοβα.Τοπικής Υπηρεσίας Περιφέρειας |
| Οργανισμός Αθήνας/Θεσσαλονίκης |
| Γεωλόγος |
| Γεωπόνος |
| Γεωτεχνικός |
| Στατικός |
| Μηχανολόγος |
| Τοπογράφος |
| Συγκοινωνιολόγος |
| ΥΠΠΟ |
| ΥΠΓΕ |
| Δ/νση Χωρ/ξίας (Κεντρική ή Περιφερειακή) |
| Διευθύνουσα Υπηρεσία |
| Δνση Περιβαλλοντικού Σχεδιασμού |
| ΥΠΕΧΩΔΕ |
| Υπουργείο Γεωργίας |
| Δνση Χωροταξίας (Κεντρική ή Περιφερειακή) |
| Δνση Χωροταξίας ΥΠΕΧΩΔΕ ή ΓΓ Περίφέρειας |
| ΕΥΠΕ/ΥΠΕΧΩΔΕ ή ΔΙΠΕΧΩ ΓΓ Περιφέρειας |
| Οικονομολόγος |
| Συναρμόδιοι Υπουργοί |
| Συναρμόδια Υπουργεία |

## Schedule

| ID | WBS | Task | Duration | Start | Finish | Predecessors | Baseline start | Baseline finish | Baseline duration | Total slack | Constraint | Resources | Work | Text1 |
| --- | --- | --- | --- | --- | --- | --- | --- | --- | --- | --- | --- | --- | --- | --- |
| 1 | 1 | Μελέτες Γενικού Σχεδιασμού / Σκοπιμότητας του Έργου | 120d | 2002-01-01 | 2002-05-01 |  |  |  |  | 0d |  | Γενικός Μελετητής; Γεωλόγος; Γεωπόνος; Γεωτεχνικός | 11520h | 4Μ |
| 2 | 2 | Διαδικασία Επιλογής Μελετητή | 152d | 2002-05-01 | 2002-09-30 | 1 |  |  |  | 0d |  | Εργοδότης | 3648h | 5Μ |
| 3 | 3 | Κατάρτιση σύμβασης-Υπογραφή Σύμβασης - Εγκατάσταση Αναδόχου | 30d | 2002-09-30 | 2002-10-30 | 2 |  |  |  | 0d |  | Εργοδότης; ΓΕΜ | 1440h | 1Μ |
| 4 | 4 | **ΣΤΑΔΙΟ Ι: Γενική Προκαταρκτική Μελέτη / Προμελέτη Περιβαλλοντικών Επιπτώσεων** | 152d | 2002-10-30 | 2003-03-31 | 3 |  |  |  | 0d |  |  | 28072h | 5Μ |
| 5 | 4.1 | Μετρήσεις Παροχών | 150d | 2002-10-30 | 2003-03-29 |  |  |  |  | 0d |  | Διευθύν. Υπηρεσία; Γενικός Μελετητής | 7200h | 18Μ |
| 6 | 4.2 | Προκαταρκτική Μελέτη | 91d | 2002-10-30 | 2003-01-29 | 5SS |  |  |  | 0d |  | Γενικός Μελετητής; Διευθύν. Υπηρεσία | 4368h | 3Μ |
| 7 | 4.3 | **Μελέτες Υποστήριξης** | 91d | 2002-10-30 | 2003-01-29 | 6SS |  |  |  | 0d |  |  | 13104h | 3Μ |
| 8 | 4.3.1 | Υδρολογική Μελέτη | 91d | 2002-10-30 | 2003-01-29 |  |  |  |  | 0d |  | Γενικός Μελετητής; Διευθύν. Υπηρεσία | 4368h | 3Μ |
| 9 | 4.3.2 | Γεωλογική Αναγνώριση | 91d | 2002-10-30 | 2003-01-29 |  |  |  |  | 0d |  | Γεωλόγος; Διευθύν. Υπηρεσία | 4368h | 3Μ |
| 10 | 4.3.3 | Υδρογεωλογική Προμελέτη | 91d | 2002-10-30 | 2003-01-29 |  |  |  |  | 0d |  | Διευθύν. Υπηρεσία; Γεωλόγος | 4368h | 3Μ |
| 11 | 4.4 | Εκπόνηση Προμελέτης Περιβαλλοντικών Επιπτώσεων-Π.Π.Ε. (Φ.Π.Χ.) | 60d | 2002-12-29 | 2003-02-27 | 7FS-31d |  |  |  | 0d |  | Διευθύν. Υπηρεσία; Γενικός Μελετητής | 2880h | 2Μ |
| 12 | 4.5 | **Διαδικασία Έκδοσης Απόφασης Προκαταρκτικής Περιβαλλοντικής Εκτίμησης και Αξιολόγησης (Π.Χ.)** | 32d | 2003-02-27 | 2003-03-31 | 11 | 2003-03-01 | 2003-03-31 | 30d | 0d |  |  | 520h | 1Μ |
| 13 | 4.5.1 | Παραλαβή Π.Π.Ε (Φ.Π.Χ.) - Έλεγχος - Υποβολή | 8d | 2003-02-27 | 2003-03-07 |  | 2003-03-01 | 2003-03-04 | 3d | 0d |  | Διευθύνουσα Υπηρεσία | 40h | 0.25 |
| 14 | 4.5.2 | Παραλαβή Π.Π.Ε (Φ.Π.Χ.) - Γνωμοδοτήσεις Συναρμοδιών | 15d | 2003-03-07 | 2003-03-22 | 13 | 2003-03-04 | 2003-03-07 | 3d | 0d |  | Συναρμόδιες Υπηρεσίες; ΕΥΠΕ/ΥΠΕΧΩΔΕ ή ΔΙΠΕΧΩ ΓΓ Περιφέρειας | 440h | 0.5Μ |
| 15 | 4.5.3 | Έκδοση Απόφασης Προκαταρκτικής Περιβαλλοντικής Εκτίμησης και Αξιολόγησης (Π.Χ.) | 9d | 2003-03-22 | 2003-03-31 | 14 | 2003-03-25 | 2003-03-31 | 6d | 0d |  | ΕΥΠΕ/ΥΠΕΧΩΔΕ ή ΔΙΠΕΧΩ ΓΓ Περιφέρειας | 40h | 0.25Μ |
| 16 | 5 | Έγκριση Σταδίου Ι | 30d | 2003-03-31 | 2003-04-30 | 12 |  |  |  | 0d |  | Εργοδότης | 720h | 1Μ |
| 17 | 6 | **ΣΤΑΔΙΟ ΙΙ: Οριστικές Μελέτες - ΜΠΕ** | 399d | 2003-04-30 | 2004-06-02 | 16 |  |  |  | 0d |  |  | 57632h | 13Μ |
| 18 | 6.1 | Οικονομοτεχνική Μελέτη και Αξιολόγηση | 62d | 2003-10-31 | 2004-01-01 | 20FF |  |  |  | 153d |  | Διευθύν. Υπηρεσία; Οικονομολόγος | 1792h | 2Μ |
| 19 | 6.2 | Ερευνες (Γεωλογικές -Γεωτεχνικές) | 92d | 2003-11-01 | 2004-02-01 | 20SS+185d |  |  |  | 122d |  | Διευθύν. Υπηρεσία; Γεωλόγος | 4416h | 3Μ |
| 20 | 6.3 | Οριστική Μελέτη (Α' Φάση) | 246d | 2003-04-30 | 2004-01-01 |  |  |  |  | 0d |  | Γενικός Μελετητής; Διευθύν. Υπηρεσία | 11808h | 8Μ |
| 21 | 6.4 | **Μελέτες Υποστήριξης (Α' Φάση)** | 185d | 2003-04-30 | 2003-11-01 | 20SS |  |  |  | 214d |  |  | 13200h | 8Μ |
| 22 | 6.4.1 | Υδρολογική μελέτη | 92d | 2003-08-01 | 2003-11-01 |  |  |  |  | 213d | start no earlier than 2003-08-01 | Γενικός Μελετητής; Διευθύν. Υπηρεσία | 4416h | 3Μ |
| 23 | 6.4.2 | Γεωλογική - Υδρογεωλογική Μελέτη | 92d | 2003-08-01 | 2003-11-01 |  |  |  |  | 213d | start no earlier than 2003-08-01 | Γεωλόγος; Διευθύν. Υπηρεσία | 4416h | 3Μ |
| 24 | 6.4.3 | Τοπογραφική Μελέτη | 91d | 2003-04-30 | 2003-07-30 |  |  |  |  | 307d |  | Τοπογράφος; Διευθύν. Υπηρεσία | 4368h | 3Μ |
| 25 | 6.5 | Έγκριση Α' Φάσης | 31d | 2004-01-01 | 2004-02-01 | 20 |  |  |  | 0d |  | Εργοδότης | 744h | 1Μ |
| 26 | 6.6 | Οριστική Μελέτη (Β' Φάση) | 122d | 2004-02-01 | 2004-06-02 | 25 |  |  |  | 0d |  |  |  | 4Μ |

| ID | WBS | Task | Duration | Start | Finish | Predecessors | Baseline start | Baseline finish | Baseline duration | Total slack | Free slack | Resources | Work | Text1 |
| --- | --- | --- | --- | --- | --- | --- | --- | --- | --- | --- | --- | --- | --- | --- |
| 27 | 6.7 | **Μελέτες Υποστήριξης (Β' Φάση)** | 92d | 2004-02-01 | 2004-05-03 | 26SS |  |  |  | 0d |  |  | 14736h | 3Μ |
| 28 | 6.7.1 | Γεωλογική Μελέτη | 92d | 2004-02-01 | 2004-05-03 |  |  |  |  | 30d |  | Διευθύν. Υπηρεσία; Γεωλόγος | 4416h | 3Μ |
| 29 | 6.7.2 | Τοπογραφική Μελέτη | 92d | 2004-02-01 | 2004-05-03 |  |  |  |  | 30d |  | Διευθύν. Υπηρεσία; Τοπογράφος | 4416h | 3Μ |
| 30 | 6.7.3 | Γεωτεχνική Μελέτη | 92d | 2004-02-01 | 2004-05-03 |  |  |  |  | 30d |  | Διευθύν. Υπηρεσία; Γεωτεχνικός | 4416h | 3Μ |
| 31 | 6.7.4 | Γεωργοτεχνική Μελέτη - Γεωργοοικονομική Μελέτη | 31d | 2004-02-01 | 2004-03-03 |  |  |  |  | 0d |  | Διευθύν. Υπηρεσία; Γεωπόνος | 1488h | 1Μ |
| 32 | 6.8 | Εκπόνηση Μελέτης Περιβαλλοντικών Επιπτώσεων | 184d | 2003-05-30 | 2003-11-30 | 16FS+30d |  |  |  | 64d | 0d | Μελετητης Περιβαλλοντολόγος; Διευθύν. Υπηρεσία | 8832h | 6Μ |
| 33 | 6.9 | **Έγκριση Μελέτης Περιβαλλοντικών Επιπτώσεων** | 121d | 2003-11-30 | 2004-03-30 | 32 | 2003-11-26 | 2004-03-31 | 126d | 64d |  |  | 2104h | 4Μ |
| 34 | 6.9.1 | Παραλάβή ΜΠΕ- Έλεγχος-Υποβολή | 15d | 2003-11-30 | 2003-12-15 |  | 2003-11-26 | 2003-12-11 | 15d | 64d | 0d | Διευθύνουσα Υπηρεσία | 80h | 0.5Μ |
| 35 | 6.9.2 | Παραλαβή της ΜΠΕ-Έλεγχος-Διαβίβαση | 17d | 2003-12-15 | 2004-01-01 | 34 | 2003-12-11 | 2004-01-10 | 30d | 64d | 0d | ΕΥΠΕ/ΥΠΕΧΩΔΕ ή ΔΙΠΕΧΩ ΓΓ Περιφέρειας | 88h | 0.5Μ |
| 36 | 6.9.3 | Παραλαβή της ΜΠΕ-Γνωμοδότηση-Διαβίβαση | 15d | 2004-01-01 | 2004-01-16 | 35 | 2003-12-26 | 2004-01-10 | 15d | 138d |  | Συναρμόδια Υπουργεία | 88h | 0.5Μ |
| 37 | 6.9.4 | Νομαρχιακό Συμβούλιο: Παραλαβή-Δημοσίευση Ανάρτηση ΜΠΕ | 15d | 2004-01-01 | 2004-01-16 | 35 | 2004-01-10 | 2004-02-09 | 30d | 64d | 0d | Νομαρχιακό Συμβούλιο | 360h | 0.5Μ |
| 38 | 6.9.5 | Διατύπωση Απόψεων - Αντιρρήσεων - Προτάσεων | 15d | 2004-01-09 | 2004-01-24 | 37FS-7d | 2004-01-25 | 2004-02-14 | 20d | 64d | 0d | Ενδιαφερόμενο Κοινό | 360h | 0.5Μ |
| 39 | 6.9.6 | Νομαρχιακό Συμβούλιο: Κριτική Άποψη Διαβίβαση | 16d | 2004-01-17 | 2004-02-02 | 38FS-7d | 2004-02-14 | 2004-02-29 | 15d | 64d | 0d | Νομαρχιακό Συμβούλιο | 360h | 0.5Μ |
| 40 | 6.9.7 | Σύνταξη Σχεδίου Απόφασης Έγκρισης Περιβαλλοντικών όρων | 28d | 2004-02-02 | 2004-03-01 | 39 | 2004-02-29 | 2004-03-15 | 15d | 64d | 0d | ΕΥΠΕ/ΥΠΕΧΩΔΕ ή ΔΙΠΕΧΩ ΓΓ Περιφέρειας | 160h | 1Μ |
| 41 | 6.9.8 | Υπογραφή Υπουργών ή Γ.Γ. Περιφέρειας | 15d | 2004-03-01 | 2004-03-16 | 40 | 2004-03-15 | 2004-03-31 | 16d | 64d | 0d | ΥΠΕΧΩΔΕ; ΓΓ Περίφέρειας; Συναρμόδιοι Υπουργοί | 528h | 0.5Μ |
| 42 | 6.9.9 | Έκδοση Απόφασης Έγκρισης Περιβαλλοντικών Όρων | 14d | 2004-03-16 | 2004-03-30 | 41 | 2004-03-31 | 2004-03-31 | 16d | 64d |  | ΕΥΠΕ/ΥΠΕΧΩΔΕ ή ΔΙΠΕΧΩ ΓΓ Περιφέρειας | 80h | 0.5Μ |
| 43 | 7 | Έγκριση Σταδίου ΙΙ | 30d | 2004-06-02 | 2004-07-02 | 17 |  |  |  | 0d |  | Εργοδότης | 720h | 1Μ |
| 44 | 8 | **ΣΤΑΔΙΟ ΙΙΙ: Σύνταξη Τευχών Δημοπράτησης** | 63d | 2004-07-02 | 2004-09-03 | 43 |  |  |  | 0d |  |  | 3024h | 2Μ |
| 45 | 8.1 | Σύνταξη Τευχών Δημοπράτησης | 63d | 2004-07-02 | 2004-09-03 |  |  |  |  | 0d |  | Διευθύν. Υπηρεσία; Γενικός Μελετητής | 3024h | 2Μ |
| 46 | 9 | Έγκριση Σταδίου ΙΙΙ | 60d | 2004-09-03 | 2004-11-02 | 44 |  |  |  | 0d |  | Εργοδότης | 1440h | 2Μ |
| 47 | 10 | **ΣΤΑΔΙΟ ΙV: : Λοιπές Εργασίες** | 244d | 2004-03-03 | 2004-11-02 |  |  |  |  | 0d |  |  | 17568h | 8Μ |
| 48 | 10.1 | Κτηματολόγιο | 244d | 2004-03-03 | 2004-11-02 | 31 |  |  |  | 0d |  | Διευθύν. Υπηρεσία; Γενικός Μελετητής; Τοπογράφος | 17568h | 8Μ |
| 49 | 10.2 | Απαλλοτριώσεις | 152d | 2004-06-03 | 2004-11-02 | 48FF |  |  |  | 0d |  |  |  | 5Μ |
