Schedule from MS Project, 2002-01-01 to 2004-08-02, 24 hours a day.
NAMA SA

## Calendars

- 24 Hours: Mon-Sun 00:00-24:00.

## Resources

| Resource |
| --- |
| Εργοδότης |
| Προιστάμενη Αρχή |
| Διευθύν. Υπηρεσία |
| Γενικός Μελετητής |
| Αλλοι τοπικοί φορείς |
| Δνση Χωροταξίας ΥΠΕΧΩΔΕ |
| ΓΓ Περίφέρειας |
| ΥΠΕΧΩΔΕ/Περιβάλλον |
| Μελετητης Περιβαλλοντολόγος |
| Δνση Περιβαλλοντικού Σχεδιασμού ΥΠΕΧΩΔΕ |
| Δνση Περιβαλλοντος και Χωροταξίας Γενικής Γραμματείας της Περιφέρειας |
| Ενδιαφερόμενο Κοινό |
| Κύριος του Έργου |
| Συναρμόδιες Υπηρεσίες |
| Δ/νση Υγιεινής-Δνση Περιβάλλοντος-Δνση Τεχνικών Υπηρεσιών Νομαρχίας |
| Εμπλεκόμενοι Δήμοι ή Κοινότητες |
| Άμεσα ενδιαφερόμενες Υπηρεσίες |
| Φορέας υλοποίησης του έργου |
| Δ.Σ. της ΔΕΥΑ |
| ΤΥΔΚ Περιφέρειας |
| Τμήμα Πρωτοβ.Τοπικής Υπηρεσίας Περιφέρειας |
| ΓΕΜ |
| Τεχνική Υπηρεσία ΟΤΑ ή ΔΕΥΑ ή ΤΥΔΚ |
| Εφορείες αρχαιοτήτων |
| Δασική Υπηρεσία |
| ΝΕΧΩΠ |
| ΕΥΠΕ/ΥΠΕΧΩΔΕ |
| Οργανισμός Αθήνας/ Θεσσαλονίκης |
| Δ/νσεις ΠΕ.ΧΩ. Περιφερειών |
| Δ/νσεις Περιβάλλοντος των Νομαρχιακών Διαμερισμάτων της ΝΑ Αττικής |
| Αρμόδιες ΔΟΥ |
| Αρμόδια Μονομέλή Πρωτοδικεία Νομών |
| Τεχν. Υπηρ. Δήμου ή Κοινότητας ή της ΔΕΥΑ |
| Δ/νση Τεχν. Υπηρ. Του ΥΠ.ΕΣ.Δ.Δ.Α |
| ΔΤΥ ΥΠ.ΕΣ.Δ.Δ.Α |
| ΔΥΠ |
| Δ/νση Πολεοδομικού Σχεδιασμού ΥΠΕΧΩΔΕ |
| Δ/νσεις Συναρμοδίων Υπουργείων |
| Δ/νση ΠΕ.ΧΩ. Τμήμα Περιβάλλοντος της Περιφέρειας |
| Νομαρχιακό Συμβούλιο |
| Αρμόδιες Υπηρεσίες χρηματοδοτήσεων (ΥΠ.ΕΘ.Ο. -ΥΠ.ΕΣ. - Περιφ.) |
| Επιτροπή Προεπιλογής Υποψήφιων Αναδόχων |
| Επιτροπή Παραλαβής προσφορών |
| Υποψήφιοι Ανάδοχοι του Έργου |
| Επιτροπή Εισήγησης για Ανάθεση |
| Ανάδοχος |
| Δνση Υγιεινής |
| ΔΤΥΝΑ Νομαρχίας |
| Δ/νση Πολεοδομίας της Ν.Α. |
| Τ. Υ. Δήμου ή Κοινότητας ή της ΔΕΥΑ |
| Τμήμα Πρωτοβα.Τοπικής Υπηρεσίας Περιφέρειας |
| Οργανισμός Αθήνας/Θεσσαλονίκης |
| Γεωλόγος |
| Γεωπόνος |
| Γεωτεχνικός |
| Στατικός |
| Μηχανολόγος |
| Τοπογράφος |
| Συγκοινωνιολόγος |
| ΥΠΠΟ |
| ΥΠΓΕ |
| Δ/νση Χωρ/ξίας (Κεντρική ή Περιφερειακή) |
| Διευθύνουσα Υπηρεσία |
| Δνση Περιβαλλοντικού Σχεδιασμού |
| ΥΠΕΧΩΔΕ |
| Υπουργείο Γεωργίας |
| Δνση Χωροταξίας (Κεντρική ή Περιφερειακή) |
| Δνση Χωροταξίας ΥΠΕΧΩΔΕ ή ΓΓ Περίφέρειας |
| ΕΥΠΕ/ΥΠΕΧΩΔΕ ή ΔΙΠΕΧΩ ΓΓ Περιφέρειας |
| Οικονομολόγος |
| Συναρμόδιοι Υπουργοί |
| Συναρμόδια Υπουργεία |

## Schedule

| ID | WBS | Task | Duration | Start | Finish | Predecessors | Baseline start | Baseline finish | Baseline duration | Total slack | Free slack | Constraint | Resources | Work | Text1 |
| --- | --- | --- | --- | --- | --- | --- | --- | --- | --- | --- | --- | --- | --- | --- | --- |
| 1 | 1 | Μελέτες Γενικού Σχεδιασμού / Σκοπιμότητας του Έργου | 120d | 2002-01-01 | 2002-05-01 |  |  |  |  | 0.33d | 0d |  | Γενικός Μελετητής; Γεωλόγος; Γεωπόνος; Γεωτεχνικός | 11520h | 4Μ |
| 2 | 2 | Διαδικασία Επιλογής Μελετητή | 153d | 2002-05-01 | 2002-10-01 | 1 |  |  |  | 0.33d | 0d |  | Εργοδότης | 3672h | 5Μ |
| 3 | 3 | Κατάρτιση σύμβασης-Υπογραφή Σύμβασης - Εγκατάσταση Αναδόχου | 31d | 2002-10-01 | 2002-11-01 | 2 |  |  |  | 0.33d | 0d |  | Εργοδότης; ΓΕΜ | 1488h | 1Μ |
| 4 | 4 | **ΣΤΑΔΙΟ Ι: Γενική Προκαταρκτική Μελέτη / Προμελέτη Περιβαλλοντικών Επιπτώσεων** | 151d | 2002-11-01 | 2003-04-01 | 3 |  |  |  | 0.33d |  |  |  | 28080h | 5Μ |
| 5 | 4.1 | Μετρήσεις Παροχών | 150d | 2002-11-01 | 2003-03-31 |  |  |  |  | 0.33d | 0d |  | Διευθύν. Υπηρεσία; Γενικός Μελετητής | 7200h | 15Μ |
| 6 | 4.2 | Προκαταρκτική Μελέτη | 91d | 2002-11-01 | 2003-01-31 | 5SS |  |  |  | 0.33d | 0d |  | Γενικός Μελετητής; Διευθύν. Υπηρεσία | 4368h | 3Μ |
| 7 | 4.3 | **Μελέτες Υποστήριξης** | 91d | 2002-11-01 | 2003-01-31 | 6SS |  |  |  | 0.33d | 0d |  |  | 13104h | 3Μ |
| 8 | 4.3.1 | Υδρολογική Μελέτη | 91d | 2002-11-01 | 2003-01-31 |  |  |  |  | 0.33d |  |  | Γενικός Μελετητής; Διευθύν. Υπηρεσία | 4368h | 3Μ |
| 9 | 4.3.2 | Γεωλογική Αναγνώριση | 91d | 2002-11-01 | 2003-01-31 |  |  |  |  | 0.33d |  |  | Γεωλόγος; Διευθύν. Υπηρεσία | 4368h | 3Μ |
| 10 | 4.3.3 | Υδρογεωλογική Προμελέτη | 91d | 2002-11-01 | 2003-01-31 |  |  |  |  | 0.33d |  |  | Διευθύν. Υπηρεσία; Γεωλόγος | 4368h | 3Μ |
| 11 | 4.4 | Εκπόνηση Προμελέτης Περιβαλλοντικών Επιπτώσεων-Π.Π.Ε. (Φ.Π.Χ.) | 60d | 2002-12-31 | 2003-03-01 | 7FS-31d |  |  |  | 0.33d | 0d |  | Διευθύν. Υπηρεσία; Γενικός Μελετητής | 2880h | 2Μ |
| 12 | 4.5 | **Διαδικασία Έκδοσης Προκαταρκτικής Περιβαλλοντικής Εκτίμησης και Αξιολόγησης (Π.Χ.)** | 31d | 2003-03-01 | 2003-04-01 | 11 | 2003-03-01 | 2003-03-31 | 30d | 0.33d | 0d |  |  | 528h | 1Μ |
| 13 | 4.5.1 | Παραλαβή Π.Π.Ε (Φ.Π.Χ.) - Έλεγχος - Υποβολή | 8d | 2003-03-01 | 2003-03-09 |  | 2003-03-01 | 2003-03-04 | 3d | 0.33d | 0d |  | Διευθύνουσα Υπηρεσία | 40h | 0.25 |
| 14 | 4.5.2 | Παραλαβή Π.Π.Ε.(Φ.Π.Χ.) - Γνωμοδοτήσεις Συναρμοδιών | 15d | 2003-03-09 | 2003-03-24 | 13 | 2003-03-04 | 2003-03-07 | 3d | 0.33d | 0d |  | Συναρμόδιες Υπηρεσίες; ΕΥΠΕ/ΥΠΕΧΩΔΕ ή ΔΙΠΕΧΩ ΓΓ Περιφέρειας | 440h | 0.5Μ |
| 15 | 4.5.3 | Έκδοση Προκαταρκτικής Περιβαλλοντικής Εκτίμησης και Αξιολόγησης (Π.Χ.) | 8d | 2003-03-24 | 2003-04-01 | 14 | 2003-03-25 | 2003-03-31 | 6d | 0.33d |  |  | ΕΥΠΕ/ΥΠΕΧΩΔΕ ή ΔΙΠΕΧΩ ΓΓ Περιφέρειας | 48h | 0.25Μ |
| 16 | 5 | Έγκριση Σταδίου Ι | 30d | 2003-04-01 | 2003-05-01 | 12 |  |  |  | 0.33d | 0d |  | Εργοδότης | 720h | 1Μ |
| 17 | 6 | **ΣΤΑΔΙΟ ΙΙ: Προμελέτες Έργων** | 305d | 2003-05-01 | 2004-03-01 | 16 |  |  |  | 0.33d | 0d |  |  | 44936h | 13Μ |
| 18 | 6.1 | Οικονομοτεχνική Μελέτη και Αξιολόγηση | 62d | 2003-11-29 | 2004-01-30 | 20FF |  |  |  | 32d |  |  | Διευθύν. Υπηρεσία; Οικονομολόγος | 1792h | 2Μ |
| 19 | 6.2 | Ερευνες (Γεωλογικές -Γεωτεχνικές) | 92d | 2003-10-01 | 2004-01-01 | 20SS+153d |  |  |  | 61d |  |  | Διευθύν. Υπηρεσία; Γεωλόγος | 4416h | 3Μ |
| 20 | 6.3 | Προμελέτη | 274d | 2003-05-01 | 2004-01-30 |  |  |  |  | 66d | 0d |  | Γενικός Μελετητής; Διευθύν. Υπηρεσία | 13152h | 9Μ |
| 21 | 6.4 | **Μελέτες Υποστήριξης (Α' Φάση)** | 184d | 2003-05-01 | 2003-11-01 | 20SS |  |  |  | 122d |  |  |  | 14688h | 8Μ |
| 22 | 6.4.1 | Υδρολογική μελέτη | 92d | 2003-08-01 | 2003-11-01 |  |  |  |  | 213d |  | start no earlier than 2003-08-01 | Γενικός Μελετητής; Διευθύν. Υπηρεσία | 4416h | 3Μ |
| 23 | 6.4.2 | Γεωλογική Μελέτη | 92d | 2003-08-01 | 2003-11-01 |  |  |  |  | 156d |  | start no earlier than 2003-08-01 | Γεωλόγος; Διευθύν. Υπηρεσία | 4416h | 3Μ |
| 24 | 6.4.3 | Τοπογραφική Μελέτη | 91d | 2003-05-01 | 2003-07-31 |  |  |  |  | 249d |  |  | Τοπογράφος; Διευθύν. Υπηρεσία | 4368h | 3Μ |
| 25 | 6.4.4 | Γεωργοτεχνική Μελέτη - Γεωργοοικονομική Μελέτη | 31d | 2003-10-01 | 2003-11-01 |  |  |  |  | 0d |  | start no earlier than 2003-10-01 | Διευθύν. Υπηρεσία; Γεωπόνος | 1488h | 1Μ |
| 26 | 6.5 | Εκπόνηση Μελέτης Περιβαλλοντικών Επιπτώσεων | 183d | 2003-05-01 | 2003-10-31 | 16 |  |  |  | 0.33d | 0d |  | Μελετητης Περιβαλλοντολόγος; Διευθύν. Υπηρεσία | 8784h | 6Μ |

| ID | WBS | Task | Duration | Start | Finish | Predecessors | Baseline start | Baseline finish | Baseline duration | Total slack | Free slack | Resources | Work | Text1 |
| --- | --- | --- | --- | --- | --- | --- | --- | --- | --- | --- | --- | --- | --- | --- |
| 27 | 6.6 | **Έγκριση Μελέτης Περιβαλλοντικών Επιπτώσεων** | 122d | 2003-10-31 | 2004-03-01 | 26 | 2003-11-26 | 2004-03-31 | 126d | 0.33d |  |  | 2104h | 4Μ |
| 28 | 6.6.1 | Παραλάβή ΜΠΕ-¨Ελεγχος-Υποβολή | 15d | 2003-10-31 | 2003-11-15 |  | 2003-11-26 | 2003-12-11 | 15d | 0.33d | 0d | Διευθύνουσα Υπηρεσία | 80h | 0.5Μ |
| 29 | 6.6.2 | Παραλαβή της ΜΠΕ-Έλεγχος-Διαβίβαση | 17d | 2003-11-15 | 2003-12-02 | 28 | 2003-12-11 | 2004-01-10 | 30d | 0.33d | 0d | ΕΥΠΕ/ΥΠΕΧΩΔΕ ή ΔΙΠΕΧΩ ΓΓ Περιφέρειας | 88h | 0.5Μ |
| 30 | 6.6.3 | Παραλαβή της ΜΠΕ-Γνωμοδότηση-Διαβίβαση | 15d | 2003-12-02 | 2003-12-17 | 29 | 2003-12-26 | 2004-01-10 | 15d | 76d |  | Συναρμόδια Υπουργεία | 88h | 0.5Μ |
| 31 | 6.6.4 | Νομαρχιακό Συμβούλιο: Παραλαβή-Δημοσίευση Ανάρτηση ΜΠΕ | 15d | 2003-12-02 | 2003-12-17 | 29 | 2004-01-10 | 2004-02-09 | 30d | 0.33d | 0d | Νομαρχιακό Συμβούλιο | 360h | 0.5Μ |
| 32 | 6.6.5 | Διατύπωση Απόψεων - Αντιρρήσεων - Προτάσεων | 15d | 2003-12-10 | 2003-12-25 | 31FS-7d | 2004-01-25 | 2004-02-14 | 20d | 0.33d | 0d | Ενδιαφερόμενο Κοινό | 360h | 0.5Μ |
| 33 | 6.6.6 | Νομαρχιακό Συμβούλιο: Κριτική Άποψη Διαβίβαση | 15d | 2003-12-18 | 2004-01-02 | 32FS-7d | 2004-02-14 | 2004-02-29 | 15d | 0.33d | 0d | Νομαρχιακό Συμβούλιο | 360h | 0.5Μ |
| 34 | 6.6.7 | Σύνταξη Σχεδίου Απόφασης Έγκρισης Περιβαλλοντικών όρων | 30d | 2004-01-02 | 2004-02-01 | 33 | 2004-02-29 | 2004-03-15 | 15d | 0.33d | 0d | ΕΥΠΕ/ΥΠΕΧΩΔΕ ή ΔΙΠΕΧΩ ΓΓ Περιφέρειας | 168h | 1Μ |
| 35 | 6.6.8 | Υπογραφή Υπουργών η Γ.Γ. Περιφέρειας | 15d | 2004-02-01 | 2004-02-16 | 34 | 2004-03-15 | 2004-03-31 | 16d | 1d | 0d | ΥΠΕΧΩΔΕ; ΓΓ Περίφέρειας; Συναρμόδιοι Υπουργοί | 520h | 0.5Μ |
| 36 | 6.6.9 | Έκδοση Απόφασης ¨Εγκρισης Περιβαλλοντικών Όρων | 14d | 2004-02-16 | 2004-03-01 | 35 | 2004-03-31 | 2004-03-31 | 16d | 1d |  | ΕΥΠΕ/ΥΠΕΧΩΔΕ ή ΔΙΠΕΧΩ ΓΓ Περιφέρειας | 80h | 0.5Μ |
| 37 | 7 | Έγκριση Σταδίου ΙΙ | 30d | 2004-03-01 | 2004-03-31 | 17 |  |  |  | 1d | 0d | Εργοδότης | 720h | 1Μ |
| 38 | 8 | **ΣΤΑΔΙΟ ΙΙΙ: Σύνταξη Τευχών Δημοπράτησης** | 61d | 2004-03-31 | 2004-05-31 | 37 |  |  |  | 1d | 0d |  | 2928h | 2Μ |
| 39 | 8.1 | Σύνταξη Τευχών Δημοπράτησης | 61d | 2004-03-31 | 2004-05-31 |  |  |  |  | 1d |  | Διευθύν. Υπηρεσία; Γενικός Μελετητής | 2928h | 2Μ |
| 40 | 9 | Έγκριση Σταδίου ΙΙΙ | 62d | 2004-05-31 | 2004-08-01 | 38 |  |  |  | 1d |  | Εργοδότης | 1488h | 2Μ |
| 41 | 10 | **ΣΤΑΔΙΟ ΙV: : Λοιπές Εργασίες** | 275d | 2003-11-01 | 2004-08-02 |  |  |  |  | 0d |  |  | 19800h | 9Μ |
| 42 | 10.1 | Κτηματολόγιο | 275d | 2003-11-01 | 2004-08-02 | 25 |  |  |  | 0d |  | Διευθύν. Υπηρεσία; Γενικός Μελετητής; Τοπογράφος | 19800h | 9Μ |
| 43 | 10.2 | Απαλλοτριώσεις | 154d | 2004-03-01 | 2004-08-02 | 42FF |  |  |  | 0d |  |  |  | 5Μ |
