# Μεταφορά νερού_new

Schedule from MS Project, 2002-01-01 to 2004-06-30, 24 hours a day.
NAMA SA

## Calendars

- 24 Hours: Mon-Sun 00:00-24:00.

## Resources

| Resource | Cost per use |
| --- | --- |
| Εργοδότης | 20145600 |
| Προιστάμενη Αρχή |  |
| Διευθύνουσα Υπηρεσία |  |
| Γενικός Μελετητής |  |
| Αλλοι τοπικοί φορείς |  |
| Μελετητής |  |
| Γεωλόγος |  |
| Δνση Χωροταξίας ΥΠΕΧΩΔΕ |  |
| ΓΓ Περίφέρειας |  |
| Δνση Χωροταξίας (Κεντρική ή Περιφερειακή) |  |
| Υπουργείο Γεωργίας |  |
| ΥΠΠΟ |  |
| ΥΠΕΧΩΔΕ/Περιβάλλον |  |
| Τοπογράφος |  |
| Γεωτεχνικός |  |
| Κυκλοφοριολόγος |  |
| Μελετητης Περιβαλλοντολόγος |  |
| Δνση Περιβαλλοντικού Σχεδιασμού |  |
| Δνση Περιβαλλοντος και Χωροταξίας Γενικής Γραμματείας της Περιφέρειας |  |
| Νομαρχιακό Συμβούλιο |  |
| Ενδιαφερόμενο Κοινό |  |
| Εδαφοτεχνικός Μελετητης |  |
| Συγκοινωνιλόγος Μηχανικός |  |
| Κύριος του Έργου |  |
| Γενικός Μελετητής(Ειδικός Συγκοινωνιολόγος) |  |
| Μελετήτής Οικονομολόγος |  |
| Δνση Χωροταξίας ΥΠΕΧΩΔΕ ή ΓΓ Περίφέρειας |  |
| ΥΠΕΧΩΔΕ |  |
| Ηλεκτρολόγος-Μηχανολόγος |  |
| ΓΕΜ |  |
| ΥΠΕΣΔΔΑ |  |
| Συναρμόδιες Υπηρεσίες |  |
| Περιβαλλοντολόγος |  |
| ΕΥΠΕ/ΥΠΕΧΩΔΕ ή ΔΙΠΕΧΩ ΓΓ Περιφέρειας |  |
| Συναρμόδιοι Υπουργοί |  |
| Συναρμόδια Υπουργεία |  |

## Schedule

| ID | WBS | Task | Type | Duration | Start | Finish | Predecessors | Baseline start | Baseline finish | Baseline duration | Total slack | Free slack | Constraint | Resources | Work | Text1 |
| --- | --- | --- | --- | --- | --- | --- | --- | --- | --- | --- | --- | --- | --- | --- | --- | --- |
| 1 | 1 | Μελέτες Γενικού σχεδιασμού - Εκθέσεις για την Τεκμηρίωση Αναγκαιότητας του Έργου |  | 58d | 2002-01-01 | 2002-02-28 |  | 2002-01-01 | 2002-02-28 | 58d | 0d |  |  | Μελετητής | 1392h | 2Μ |
| 2 | 2 | **Διαδικασία Επιλογής Μελετητή** |  | 153d | 2002-02-28 | 2002-07-31 | 1 | 2002-01-11 | 2002-01-11 | 0.33d? | 0d |  |  | Εργοδότης | 8448h | 5Μ |
| 3 | 2.1 | Δημοσίευση Προκήρυξης Μελέτης |  | 45d | 2002-02-28 | 2002-04-14 |  | 2002-01-11 | 2002-01-11 | 0.33d? | 0d |  |  | Εργοδότης | 1080h | 1.5Μ |
| 4 | 2.2 | Αξιολόγηση Υποψήφιων μελετητών |  | 31d | 2002-04-14 | 2002-05-15 | 3 | 2002-04-14 | 2002-05-15 | 31d | 0d |  |  | Εργοδότης | 744h | 1Μ |
| 5 | 2.3 | Επιλογή Μελετητή |  | 15d | 2002-05-15 | 2002-05-30 | 4 | 2002-05-15 | 2002-05-30 | 15d | 0d |  |  | Εργοδότης | 360h | 0.5Μ |
| 6 | 2.4 | Κοινοποίηση Απόφασης Ανάθεσης |  | 16d | 2002-05-30 | 2002-06-15 | 5 | 2002-05-30 | 2002-06-15 | 16d | 0d |  |  | Εργοδότης | 384h | 0.5Μ |
| 7 | 2.5 | Διαδικασία Ενστάσεων |  | 46d | 2002-06-15 | 2002-07-31 | 6 | 2002-06-15 | 2002-08-31 | 77d | 0d |  |  | Εργοδότης; ΓΕΜ | 2208h | 1.5Μ |
| 8 | 2.6 | Ανάθεση Μελέτης | milestone | 0d | 2002-07-31 | 2002-07-31 | 7 | 2002-08-31 | 2002-08-31 | 0d? | 0d |  |  | Εργοδότης |  | 0Μ |
| 9 | 3 | Κατάρτιση Σύμβασης - Υπογραφή Σύμβασης - Εγκατάσταση Αναδόχου |  | 30d | 2002-07-31 | 2002-08-30 | 8 | 2002-08-31 | 2002-10-01 | 31d | 0d |  |  | Εργοδότης; Προιστάμενη Αρχή; Διευθύνουσα Υπηρεσία; Γενικός Μελετητής | 2880h | 1Μ |
| 10 | 4 | Επίβλεψη Μελέτης |  | 670d | 2002-08-30 | 2004-06-30 | 9 | 2002-10-01 | 2004-06-30 | 638d | 0d |  |  | Διευθύνουσα Υπηρεσία; Γενικός Μελετητής | 32160h | 22Μ |
| 11 | 5 | Εποπτεία Μελέτης |  | 670d | 2002-08-30 | 2004-06-30 | 10SS | 2002-10-01 | 2004-06-30 | 638d | 0d |  |  | Προιστάμενη Αρχή; Γενικός Μελετητής | 32160h | 22Μ |
| 12 | 6 | **ΣΤΑΔΙΟ Ι: Προκαταρκτική Μελέτη Έργου / Π.Π.Ε** |  | 182d | 2002-08-30 | 2003-02-28 | 11SS | 2002-10-01 | 2003-02-28 | 150d | 1d |  |  |  | 24672h | 6Μ |
| 13 | 6.1 | Μέτρηση Παροχών - Έλεγχος Καταλληλότητας Νερού |  | 182d | 2002-08-30 | 2003-02-28 |  | 2002-10-01 | 2002-11-30 | 60d | 488d |  |  | Διευθύνουσα Υπηρεσία; Γενικός Μελετητής | 8736h | 6M |
| 14 | 6.2 | Προκαταρκτική μελέτη |  | 123d | 2002-08-30 | 2002-12-31 |  | 2002-10-01 | 2003-01-31 | 122d | 1d | 0d |  | Διευθύνουσα Υπηρεσία; Γενικός Μελετητής | 5904h | 4Μ |
| 15 | 6.3 | Υδρολογική Μελέτη |  | 61d | 2002-11-01 | 2003-01-01 |  | 2002-11-01 | 2003-01-01 | 61d | 546.33d |  | start no earlier than 2002-11-01 | Διευθύνουσα Υπηρεσία; Γενικός Μελετητής | 2928h | 2Μ |
| 16 | 6.4 | Γεωλογική Αναγνώριση |  | 61d | 2002-11-01 | 2003-01-01 |  | 2002-11-01 | 2003-01-01 | 61d | 546.33d |  | start no earlier than 2002-11-01 | Διευθύνουσα Υπηρεσία; Γενικός Μελετητής; Γεωλόγος | 4392h | 1Μ |
| 17 | 6.5 | Εκπόνηση Προμελέτης Περιβαλλοντικών Επιπτώσεων -Π.Π.Ε. (Φ.Π.Χ.) - Υποβολή |  | 30d | 2002-12-31 | 2003-01-30 | 14 | 2003-01-31 | 2003-02-28 | 28d | 1d | 0d |  | Διευθύνουσα Υπηρεσία; Γενικός Μελετητής; Περιβαλλοντολόγος | 1616h | 1Μ |
| 18 | 6.6 | **Διαδικασία Έκδοσης Απόφασης Προκαταρκτικής Περιβαλλοντικής Εκτίμησης και Αξιολόγησης (Π.Χ.)** |  | 29d | 2003-01-30 | 2003-02-28 | 17 | 2003-02-28 | 2003-03-31 | 31d | 1d | 0d |  | Εργοδότης | 1096h | 1Μ |
| 19 | 6.6.1 | Παραλαβή Π.Π.Ε (Φ.Π.Χ.) - Έλεγχος - Υποβολή |  | 7d | 2003-01-30 | 2003-02-06 |  | 2003-02-28 | 2003-03-05 | 5d | 1d | 0d |  | Διευθύνουσα Υπηρεσία; ΕΥΠΕ/ΥΠΕΧΩΔΕ ή ΔΙΠΕΧΩ ΓΓ Περιφέρειας | 208h | 0.25Μ |
| 20 | 6.6.2 | Παραλαβή Π.Π.Ε.(Φ.Π.Χ.) - Γνωμοδοτήσεις Συναρμοδιών |  | 15d | 2003-02-06 | 2003-02-21 | 19 | 2003-03-05 | 2003-03-10 | 5d | 1d | 0d |  | Διευθύνουσα Υπηρεσία; Συναρμόδιες Υπηρεσίες; ΕΥΠΕ/ΥΠΕΧΩΔΕ ή ΔΙΠΕΧΩ ΓΓ Περιφέρειας | 152h | 0.5Μ |
| 21 | 6.6.3 | Έκδοση Απόφασης Προκαταρκτικής Περιβαλλοντικής Εκτίμησης και Αξιολόγησης (Π.Χ.) |  | 7d | 2003-02-21 | 2003-02-28 | 20 | 2003-03-25 | 2003-03-31 | 6d | 1d |  |  | ΕΥΠΕ/ΥΠΕΧΩΔΕ ή ΔΙΠΕΧΩ ΓΓ Περιφέρειας | 40h | 0.25Μ |
| 22 | 7 | Έγκριση Σταδίου Ι |  | 31d | 2003-02-28 | 2003-03-31 | 18 | 2003-03-31 | 2003-04-30 | 30d | 1d | 0d |  | Εργοδότης | 744h | 1Μ |
| 23 | 8 | **ΣΤΑΔΙΟ ΙΙ: Προμελέτη Έργου** |  | 92d | 2003-03-31 | 2003-07-01 | 22 | 2003-03-31 | 2003-07-01 | 92d | 1d | 0d |  |  | 15984h | 3Μ |
| 24 | 8.1 | **Μελέτες Υποστήριξης** |  | 92d | 2003-03-31 | 2003-07-01 |  | 2003-03-31 | 2003-07-01 | 92d | 1d |  |  |  | 10080h | 2Μ |
| 25 | 8.1.1 | Υδρολογική |  | 60d | 2003-03-31 | 2003-05-30 |  | 2003-03-31 | 2003-05-30 | 60d | 32d |  |  | Διευθύνουσα Υπηρεσία; Γενικός Μελετητής | 2880h | 2Μ |
| 26 | 8.1.2 | Γεωλογική |  | 60d | 2003-03-31 | 2003-05-30 |  | 2003-03-31 | 2003-05-30 | 60d | 32d |  |  | Διευθύνουσα Υπηρεσία; Γενικός Μελετητής; Γεωλόγος | 4320h | 2Μ |
| 27 | 8.1.3 | Τοπογραφική |  | 60d | 2003-03-31 | 2003-05-30 |  | 2003-03-31 | 2003-05-30 | 60d | 1d | 0d |  | Διευθύνουσα Υπηρεσία; Τοπογράφος | 2880h | 2Μ |
| 28 | 8.1.4 | Μέτρηση Παροχών -Έλεγχος Καταλληλότητας Νερού |  | 92d | 2003-03-31 | 2003-07-01 |  | 2003-03-31 | 2003-07-01 | 92d | 1d |  |  |  |  | 3Μ |
| 29 | 8.2 | Προμελέτη(Γενική Διάταξη Έργου - Ειδικά Τεχνικά Έργα) |  | 92d | 2003-03-31 | 2003-07-01 |  | 2003-03-31 | 2003-07-01 | 92d | 1d | 0d |  | Διευθύνουσα Υπηρεσία; Γενικός Μελετητής | 4416h | 3Μ |
| 30 | 8.3 | Οικονομοτεχνική Μελέτη και Αξιολόγηση |  | 31d | 2003-05-31 | 2003-07-01 | 29FF | 2002-12-31 | 2003-01-31 | 31d | 1d |  |  | Διευθύνουσα Υπηρεσία; Γενικός Μελετητής | 1488h | 1Μ |
| 31 | 9 | Έγκριση Σταδίου ΙΙ |  | 31d | 2003-07-01 | 2003-08-01 | 23 | 2003-07-01 | 2003-08-01 | 31d | 1d | 0d |  | Εργοδότης | 744h | 1Μ |
| 32 | 10 | Γεωλογικές και Γεωτεχνικές Έρευνες |  | 183d | 2003-05-01 | 2003-10-31 | 23SS+31d | 2003-05-01 | 2003-10-31 | 183d | 243d |  |  | Διευθύνουσα Υπηρεσία; Γεωλόγος; Γεωτεχνικός | 13176h | 6Μ |

Notes:
- 30: βγήκε από την προκαταρκτική και μπήκε στην προμελέτη(Α' Φάση)

| ID | WBS | Task | Type | Duration | Start | Finish | Predecessors | Baseline start | Baseline finish | Baseline duration | Total slack | Free slack | Constraint | Resources | Work | Text1 |
| --- | --- | --- | --- | --- | --- | --- | --- | --- | --- | --- | --- | --- | --- | --- | --- | --- |
| 33 | 11 | **ΣΤΑΔΙΟ ΙΙΙ: Οριστική Μελέτη Έργου / Μ.Π.Ε** |  | 242d | 2003-08-01 | 2004-03-30 | 31 | 2003-04-30 | 2003-12-31 | 245d | 1d |  |  |  | 19432h | 2Μ |
| 34 | 11.1 | **Μελέτες Υποστήριξης** |  | 61d | 2003-08-01 | 2003-10-01 |  | 2003-04-30 | 2003-06-29 | 60d | 1d |  |  |  | 5856h | 2Μ |
| 35 | 11.1.1 | Γεωτεχνική Μελέτη |  | 61d | 2003-08-01 | 2003-10-01 |  | 2003-04-30 | 2003-06-29 | 60d | 273d |  |  | Διευθύνουσα Υπηρεσία; Γεωτεχνικός | 2928h | 2Μ |
| 36 | 11.1.2 | Τοπογραφική μελέτη |  | 61d | 2003-08-01 | 2003-10-01 |  | 2003-04-30 | 2003-06-29 | 60d | 1d | 0d |  | Διευθύνουσα Υπηρεσία; Τοπογράφος | 2928h | 2Μ |
| 37 | 11.2 | Οριστική Μελέτη |  | 123d | 2003-10-01 | 2004-02-01 | 36 | 2003-06-29 | 2003-11-29 | 153d | 150d |  | start no earlier than 2003-04-27 | Διευθύνουσα Υπηρεσία; Γενικός Μελετητής | 5904h | 4Μ |
| 38 | 11.3 | Εκπόνηση Μελέτης Περιβαλλοντικών Επιπτώσεων |  | 91d | 2003-08-31 | 2003-11-30 | 36FS-31d | 2003-08-28 | 2003-11-26 | 90d | 1d | 0d |  | Διευθύνουσα Υπηρεσία; Γενικός Μελετητής | 4368h | 3Μ |
| 39 | 11.4 | **Έγκριση Μελέτης Περιβαλλοντικών Επιπτώσεων** |  | 121d | 2003-11-30 | 2004-03-30 | 38 | 2003-11-26 | 2004-03-31 | 126d | 1d | 0d |  |  | 2560h | 4Μ |
| 40 | 11.4.1 | Παραλάβή ΜΠΕ-Έλεγχος-Υποβολή |  | 15d | 2003-11-30 | 2003-12-15 |  | 2003-11-26 | 2003-12-11 | 15d | 1d | 0d |  | Διευθύνουσα Υπηρεσία | 360h | 0.5Μ |
| 41 | 11.4.2 | Παραλαβή της ΜΠΕ-Έλεγχος-Διαβίβαση |  | 15d | 2003-12-15 | 2003-12-30 | 40 | 2003-12-11 | 2004-01-10 | 30d | 1d | 0d |  | ΕΥΠΕ/ΥΠΕΧΩΔΕ ή ΔΙΠΕΧΩ ΓΓ Περιφέρειας | 88h | 0.5Μ |
| 42 | 11.4.3 | Παραλαβή της ΜΠΕ-Γνωμοδότηση-Διαβίβαση |  | 14d | 2003-12-30 | 2004-01-13 | 41 | 2003-12-26 | 2004-01-10 | 15d | 78d |  |  | Συναρμόδια Υπουργεία | 80h | 0.5Μ |
| 43 | 11.4.4 | Νομαρχιακό Συμβούλιο: Παραλαβή-Δημοσίευση Ανάρτηση ΜΠΕ |  | 14d | 2003-12-30 | 2004-01-13 | 41 | 2004-01-10 | 2004-02-09 | 30d | 1d | 0d |  | Νομαρχιακό Συμβούλιο | 336h | 0.5Μ |
| 44 | 11.4.5 | Διατύπωση Απόψεων - Αντιρρήσεων - Προτάσεων |  | 14d | 2004-01-08 | 2004-01-22 | 43FS-5d | 2004-01-25 | 2004-02-14 | 20d | 1d | 0d |  | Ενδιαφερόμενο Κοινό | 336h | 0.5Μ |
| 45 | 11.4.6 | Νομαρχιακό Συμβούλιο: Κριτική Άποψη Διαβίβαση |  | 14d | 2004-01-17 | 2004-01-31 | 44FS-5d | 2004-02-14 | 2004-02-29 | 15d | 1d | 0d |  | Νομαρχιακό Συμβούλιο | 336h | 0.5Μ |
| 46 | 11.4.7 | Σύνταξη Σχεδίου Απόφασης Έγκρισης Περιβαλλοντικών Όρων |  | 29d | 2004-01-31 | 2004-02-29 | 45 | 2004-02-29 | 2004-03-15 | 15d | 1d | 0d |  | ΕΥΠΕ/ΥΠΕΧΩΔΕ ή ΔΙΠΕΧΩ ΓΓ Περιφέρειας | 160h | 1Μ |
| 47 | 11.4.8 | Υπογραφή Υπουργών ή Γ.Γ. Περιφέρειας |  | 15d | 2004-02-29 | 2004-03-15 | 46 | 2004-03-15 | 2004-03-31 | 16d | 1d | 0d |  | ΓΓ Περίφέρειας; Συναρμόδιοι Υπουργοί; ΥΠΕΧΩΔΕ | 800h | 0.5Μ |
| 48 | 11.4.9 | Έκδοση Απόφασης Έγκρισης Περιβαλλοντικών Όρων | milestone | 15d | 2004-03-15 | 2004-03-30 | 47 | 2004-03-31 | 2004-03-31 | 0d? | 1d |  |  | ΕΥΠΕ/ΥΠΕΧΩΔΕ ή ΔΙΠΕΧΩ ΓΓ Περιφέρειας | 64h | 0.5Μ |
| 49 | 11.5 | Έγκριση Σταδίου ΙΙΙ |  | 31d | 2004-02-28 | 2004-03-30 | 39FF | 2004-02-29 | 2004-03-31 | 31d | 1d | 0d |  | Εργοδότης | 744h | 1Μ |
| 50 | 12 | **ΣΤΑΔΙΟ IV: Λοιπές Ενέργειες** |  | 396d | 2003-05-30 | 2004-06-29 |  | 2003-03-31 | 2004-06-30 | 457d | 1d |  |  |  | 26328h | 16Μ |
| 51 | 12.1 | Κτηματολόγιο |  | 305d | 2003-05-30 | 2004-03-30 | 27 | 2003-03-31 | 2004-02-29 | 335d | 1d |  |  | Διευθύνουσα Υπηρεσία; Γενικός Μελετητής; Τοπογράφος | 21960h | 10Μ |
| 52 | 12.2 | Απαλλοτριώσεις |  | 91d | 2004-03-30 | 2004-06-29 | 49, 51 | 2003-12-31 | 2004-06-30 | 182d | 1d | 0d |  |  |  | 3Μ |
| 53 | 12.3 | Σύνταξη και Έγκριση Τευχών Δημοπράτησης |  | 91d | 2004-03-30 | 2004-06-29 | 52SS | 2003-12-31 | 2004-03-31 | 91d | 1d |  |  | Διευθύνουσα Υπηρεσία; Γενικός Μελετητής | 4368h | 3Μ |
