Schedule from MS Project, 2002-01-01 to 2005-12-31, 24 hours a day.
NAMA SA

## Calendars

- 24 Hours: Mon-Sun 00:00-24:00.

## Resources

| Resource |
| --- |
| Εργοδότης |
| Προιστάμενη Αρχή |
| Διευθύνουσα Υπηρεσία |
| Γεν. Μελετητής |
| Αλλοι τοπικοί φορείς |
| Δ/νση Χωροταξίας ΥΠΕΧΩΔΕ |
| ΓΓ Περίφέρειας |
| ΥΠΕΧΩΔΕ/Περιβάλλον |
| Μελετητής Περιβαλλοντολόγος |
| Δ/νση Περιβαλλοντικού Σχεδιασμού ΥΠΕΧΩΔΕ |
| Δ/νση Περιβαλλοντος και Χωροταξίας Γενικής Γραμματείας της Περιφέρειας |
| Ενδιαφερόμενο Κοινό |
| Κύριος του Έργου |
| Συναρμόδιες Υπηρεσίες |
| Δ/νση Υγιεινής-Δ/νση Περιβάλλοντος-ΔΤΥΝΑ |
| Εμπλεκόμενοι Δήμοι ή Κοινότητες |
| Ενδιαφερόμενες Υπηρεσίες |
| Φορέας υλοποίησης του έργου |
| Δ.Σ. της ΔΕΥΑ |
| ΤΥΔΚ Περιφέρειας |
| Τμήμα Πρωτοβ.Τοπικής Υπηρεσίας Περιφέρειας |
| ΓΕΜ |
| Τεχνική Υπηρεσία ΟΤΑ ή ΔΕΥΑ ή ΤΥΔΚ |
| Εφορείες αρχαιοτήτων |
| Δασική Υπηρεσία |
| ΝΕΧΩΠ |
| ΕΥΠΕ/ΥΠΕΧΩΔΕ |
| Οργανισμός Αθήνας/ Θεσσαλονίκης |
| Δ/νσεις ΠΕ.ΧΩ. Περιφερειών |
| Δ/νσεις Περιβάλλοντος των Νομαρχιακών Διαμερισμάτων της ΝΑ Αττικής |
| Αρμόδιες ΔΟΥ |
| Αρμόδια Μονομέλή Πρωτοδικεία Νομών |
| Τεχν. Υπηρ. Δήμου ή Κοινότητας ή της ΔΕΥΑ |
| Δ/νση Τεχν. Υπηρ. Του ΥΠ.ΕΣ.Δ.Δ.Α |
| ΔΤΥ ΥΠ.ΕΣ.Δ.Δ.Α |
| ΔΥΠ |
| Δ/νση Πολεοδομικού Σχεδιασμού ΥΠΕΧΩΔΕ |
| Δ/νσεις Συναρμοδίων Υπουργείων |
| Δ/νση ΠΕ.ΧΩ. Τμήμα Περιβάλλοντος της Περιφέρειας |
| Νομαρχιακό Συμβούλιο |
| Αρμόδιες Υπηρεσίες χρηματοδοτήσεων (ΥΠ.ΕΘ.Ο. -ΥΠ.ΕΣ. - Περιφ.) |
| Επιτροπή Προεπιλογής Υποψήφιων Αναδόχων |
| Επιτροπή Παραλαβής προσφορών |
| Υποψήφιοι Ανάδοχοι του Έργου |
| Επιτροπή Εισήγησης για Ανάθεση |
| Ανάδοχος |
| Δ/νση Υγιεινής |
| ΔΤΥΝΑ Νομαρχίας |
| Δ/νση Πολεοδομίας της Ν.Α. |
| Τ. Υ. Δήμου ή Κοινότητας ή της ΔΕΥΑ |
| Τμήμα Πρωτοβα.Τοπικής Υπηρεσίας Περιφέρειας |
| Οργανισμός Αθήνας/Θεσσαλονίκης |
| Νομάρχης |
| Ειδική Επιτροπή |
| Τοπογράφος |
| Γεωλόγος |
| Γεωτεχνικός |
| Η/Μ |
| Στατικός |
| ΕΥΠΕ/ΥΠΕΧΩΔΕ ή ΔΙΠΕΧΩ ΓΓ Περιφέρειας |

## Schedule

| ID | WBS | Task | Type | Duration | Start | Finish | Predecessors | Baseline start | Baseline finish | Baseline duration | Total slack | Free slack | Constraint | Resources | Work | Text1 |
| --- | --- | --- | --- | --- | --- | --- | --- | --- | --- | --- | --- | --- | --- | --- | --- | --- |
| 1 | 1 | **Διαδικασία Επιλογής μελετητή** |  | 181d | 2002-01-01 | 2002-07-01 |  | 2002-01-11 | 2002-01-11 | 0.33d? | 92d | 0d |  | Εργοδότης | 10488h | 6Μ |
| 2 | 1.1 | Δημοσίευση Προκήρυξης Μελέτης |  | 45d | 2002-01-01 | 2002-02-15 |  | 2002-01-11 | 2002-01-11 | 0.33d? | 92d | 0d |  | Εργοδότης | 1080h | 1.5Μ |
| 3 | 1.2 | Αξιολόγηση Υποψήφιων μελετητών |  | 31d | 2002-02-15 | 2002-03-18 | 2 | 2002-04-14 | 2002-05-15 | 31d | 92d | 0d |  | Εργοδότης | 744h | 1Μ |
| 4 | 1.3 | Επιλογή μελετητή |  | 15d | 2002-03-18 | 2002-04-02 | 3 | 2002-05-15 | 2002-05-30 | 15d | 92d | 0d |  | Εργοδότης | 360h | 0.5Μ |
| 5 | 1.4 | Κοινοποίηση Απόφασης Ανάθεσης |  | 15d | 2002-04-02 | 2002-04-17 | 4 | 2002-05-30 | 2002-06-15 | 16d | 92d | 0d |  | Εργοδότης | 360h | 0.5Μ |
| 6 | 1.5 | Διαδικασία ενστάσεων |  | 75d | 2002-04-17 | 2002-07-01 | 5 | 2002-06-15 | 2002-08-31 | 77d | 92d | 0d |  | Εργοδότης; ΓΕΜ | 3600h | 2.5Μ |
| 7 | 1.6 | Ανάθεση Μελέτης | milestone | 0d | 2002-07-01 | 2002-07-01 | 6 | 2002-08-31 | 2002-08-31 | 0d? | 92d |  |  | Εργοδότης |  | 0Μ |
| 8 | 2 | Κατάρτιση Σύμβασης - Υπογραφή Σύμβασης - Έγκατάσταση Αναδόχου |  | 30d | 2002-07-01 | 2002-07-31 | 1 |  |  |  | 92d | 0d |  |  |  | 1Μ |
| 9 | 3 | **ΣΤΑΔΙΟ Ι: Γενική Προκαταρκτική Μελέτη / Προμελέτη Περιβαλλοντικών Επιπτώσεων** |  | 243d | 2002-07-31 | 2003-03-31 | 8 |  |  |  | 92d |  |  | Διευθύνουσα Υπηρεσία; Γεν. Μελετητής | 29448h | 8Μ |
| 10 | 3.1 | Γενική Προκαταρκτική Μελέτη του όλου Συστήματος Αποχέτευσης |  | 61d | 2002-07-31 | 2002-09-30 |  |  |  |  | 92d | 0d |  | Διευθύνουσα Υπηρεσία; Γεν. Μελετητής | 2928h | 2Μ |
| 11 | 3.2 | Οικονομοτεχνική Μελέτη |  | 61d | 2002-07-31 | 2002-09-30 | 10SS |  |  |  | 92d | 0d |  | Διευθύνουσα Υπηρεσία; Γεν. Μελετητής | 2928h | 2Μ |
| 12 | 3.3 | Αναγνώριση και Κατάταξη Αποδέκτη |  | 61d | 2002-07-31 | 2002-09-30 | 11SS |  |  |  | 92d | 0d |  | Δ/νση Υγιεινής-Δ/νση Περιβάλλοντος-ΔΤΥΝΑ; Εμπλεκόμενοι Δήμοι ή Κοινότητες; Ενδιαφερόμενες Υπηρεσίες | 4392h | 2Μ |
| 13 | 3.4 | Έγκριση Αποδέκτη |  | 61d | 2002-09-30 | 2002-11-30 | 12 |  |  |  | 1127d |  |  | Νομάρχης; Ειδική Επιτροπή | 688h | 2Μ |
| 14 | 3.5 | Εκπόνηση Προμελέτης Περιβαλλοντικών Επιπτώσεων-Π.Π.Ε. (Φ.Π.Χ.) |  | 30d | 2002-08-31 | 2002-09-30 | 12FF |  |  |  | 92d | 0d |  | Διευθύνουσα Υπηρεσία; Γεν. Μελετητής | 1440h | 1Μ |
| 15 | 3.6 | Υποβολή Π.Π.Ε. (Φ.Π.Χ.) - Έκδοση Απόφασης Π.Π.Ε.Α (Π.Χ.) - Έναρξη Εργασιών Απόκτησης Οικοπέδου |  | 182d | 2002-09-30 | 2003-03-31 | 14 |  |  |  | 92d | 0d |  | Διευθύνουσα Υπηρεσία; ΕΥΠΕ/ΥΠΕΧΩΔΕ ή ΔΙΠΕΧΩ ΓΓ Περιφέρειας | 5408h | 6Μ |
| 16 | 4 | Έγκριση Σταδίου Ι (Προκαταρκτική Μελέτη) για έργα>800εκ |  | 182d | 2002-09-30 | 2003-03-31 | 15SS |  |  |  | 92d | 0d |  | Εργοδότης | 4368h | 6Μ |
| 17 | 5 | **Στάδιο ΙΙ: Εκπόνηση Προμελετών - Μελέτη Περιβαλλοντικών Επιπτώσεων** |  | 214d | 2003-03-31 | 2003-10-31 | 16 |  |  |  | 92d |  |  |  | 59200h | 12Μ |
| 18 | 5.1 | Προμελέτη Δικτύου Συλλογής Ακαθάρτων |  | 185d | 2003-03-31 | 2003-10-02 |  |  |  |  | 821d |  |  | Διευθύνουσα Υπηρεσία; Γεν. Μελετητής | 8880h | 6M |
| 19 | 5.2 | Μελέτες Υποστήριξης Δικτύου Συλλογής Ακαθάρτων |  | 185d | 2003-03-31 | 2003-10-02 |  |  |  |  | 821d |  |  | Διευθύνουσα Υπηρεσία; Τοπογράφος; Γεωλόγος; Γεωτεχνικός; Η/Μ | 8640h | 6M |
| 20 | 5.3 | Προμελέτη Εγκατάστασεων Επεξεργασίας Λυμάτων (Ε.Ε.Λ.) |  | 185d | 2003-03-31 | 2003-10-02 |  |  |  |  | 821d |  |  | Διευθύνουσα Υπηρεσία; Γεν. Μελετητής | 8880h | 6M |
| 21 | 5.4 | Μελέτες Υποστήριξης Εγκατάστασεων Επεξεργασίας Λυμάτων (Ε.Ε.Λ.) |  | 185d | 2003-03-31 | 2003-10-02 |  |  |  |  | 821d |  |  | Διευθύνουσα Υπηρεσία; Τοπογράφος; Γεωλόγος; Γεωτεχνικός; Η/Μ; Στατικός | 9696h | 6M |
| 22 | 5.5 | Προμελέτη Έργων Διάθεσης Λυμάτων στη Θάλασσα |  | 185d | 2003-03-31 | 2003-10-02 |  |  |  |  | 821d |  |  | Διευθύνουσα Υπηρεσία; Γεν. Μελετητής | 8880h | 6M |
| 23 | 5.6 | Μελέτες Υποστήριξης Διάθεσης Λυμάτων στη Θάλασσα |  | 185d | 2003-03-31 | 2003-10-02 |  |  |  |  | 821d |  |  | Διευθύνουσα Υπηρεσία; Γεν. Μελετητής; Τοπογράφος; Γεωλόγος | 10944h | 6M |
| 24 | 5.7 | Εκπόνηση Μελέτης Περιβαλλοντικών Επιπτωσεων (ΜΠΕ) |  | 61d | 2003-07-01 | 2003-08-31 |  |  |  |  | 0d |  | start no earlier than 2003-07-01 | Διευθύνουσα Υπηρεσία; Μελετητής Περιβαλλοντολόγος | 2928h | 2Μ |
| 25 | 5.8 | Έγκριση Περιβαλλοντικών Όρων |  | 61d | 2003-08-31 | 2003-10-31 | 24 |  |  |  | 0d |  | start no earlier than 2003-08-01 | ΕΥΠΕ/ΥΠΕΧΩΔΕ ή ΔΙΠΕΧΩ ΓΓ Περιφέρειας | 352h | 2Μ |
| 26 | 6 | Εγκριση Προμελετών |  | 182d | 2003-10-31 | 2004-04-30 | 25 |  |  |  | 0d |  | start no earlier than 2003-10-01 | Εργοδότης | 4368h | 6Μ |

| ID | WBS | Task | Duration | Start | Finish | Predecessors | Total slack | Free slack | Resources | Work | Text1 |
| --- | --- | --- | --- | --- | --- | --- | --- | --- | --- | --- | --- |
| 27 | 7 | **Στάδιο ΙΙΙ: Εκπόνηση Οριστικών Μελετών και Τευχών Δημοπράτησης** | 610d | 2004-04-30 | 2005-12-31 | 26 | 0d |  |  | 35112h | 20Μ |
| 28 | 7.1 | Οριστική Μελέτη Δικτύου Συλλογής Ακαθάρτων | 185d | 2004-04-30 | 2004-11-01 |  | 0d |  | Διευθύνουσα Υπηρεσία; Γεν. Μελετητής | 8880h | 6Μ |
| 29 | 7.2 | Σύνταξη των Τευχών Δημοπράτησης Ε.Ε.Λ. (Σύστημα Μ-Κ) | 61d | 2004-04-30 | 2004-06-30 |  | 368d | 0d | Διευθύνουσα Υπηρεσία; Γεν. Μελετητής | 2928h | 2Μ |
| 30 | 7.3 | Σύνταξη των Τευχών Δημοπράτησης Έργων Διάθεσης Λυμάτων (Σύστημα Μ-Κ και με Συμπλήρωση Τιμολογίου) | 61d | 2004-04-30 | 2004-06-30 |  | 368d | 0d | Διευθύνουσα Υπηρεσία; Γεν. Μελετητής | 2928h | 2Μ |
| 31 | 7.4 | Έγκριση Οριστικής Μελέτης Δικτύου Συλλογής Ακαθάρτων | 181d | 2004-11-01 | 2005-05-01 | 28 | 0d |  | Διευθύνουσα Υπηρεσία | 4344h | 6Μ |
| 32 | 7.5 | Έγκριση των Τευχών Δημοπράτησης Ε.Ε.Λ. | 181d | 2004-06-30 | 2004-12-28 | 29 | 368d |  | Διευθύνουσα Υπηρεσία | 4344h | 6Μ |
| 33 | 7.6 | Έγκριση των Τευχών Δημοπράτησης Έργων Διάθεσης Λυμάτων | 181d | 2004-06-30 | 2004-12-28 | 30 | 368d |  | Διευθύνουσα Υπηρεσία | 4344h | 6Μ |
| 34 | 7.7 | Σύνταξη των Τευχών Δημοπράτησης Δικτύου Συλλογής Ακαθάρτων (Σύστημα με Συμπλήρωση Τιμολογίου) | 62d | 2005-05-01 | 2005-07-02 | 31 | 0d |  | Διευθύνουσα Υπηρεσία; Γεν. Μελετητής | 2976h | 2Μ |
| 35 | 7.8 | Έγκριση των Τευχών Δημοπράτησης Δικτύου Συλλογής Ακαθάρτων | 182d | 2005-07-02 | 2005-12-31 | 34 | 0d |  | Διευθύνουσα Υπηρεσία | 4368h | 6Μ |
| 36 | 8 | Απαλλοτρίωσεις Οικοπέδου | 609d | 2003-03-31 | 2004-11-29 | 16 | 397d |  |  |  | 20Μ |
| 37 | 9 | Λήψη Αδειών και Σχετικών Γνωμοδοτήσεων για τα Έργα Διάθεσης Λυμάτων | 427d | 2003-10-29 | 2004-12-29 | 26FS-184d | 367d |  |  |  | 14Μ |
| 38 | 10 | Σύσταση Δουλειας - Απαλλοτροιώσεις (για δίκτυο συλλογής) | 425d | 2004-11-01 | 2005-12-31 | 31SS | 0d |  |  |  | 14Μ |
